# ALTESA

Schedule from Primavera P6, 2024-06-13 to 2025-11-17, data date 2024-06-13.

## Calendars

- FYA DC: Mon-Sun 08:00-18:00. Exceptions (off unless hours are given): 2025-01-01 to 2025-04-30.

## Schedule

| ID | WBS | Activity | Type | Duration | Start | Finish | Predecessors | Total float | Free float | Constraint | MSP Outline Number | MSP Unique ID | MSP Project Name | Imported Early Start | Imported Late Start | Imported Start | Imported Early Finish | Imported Late Finish | Imported Finish | MSP ID | MSP Task Order |
| --- | --- | --- | --- | --- | --- | --- | --- | --- | --- | --- | --- | --- | --- | --- | --- | --- | --- | --- | --- | --- | --- |
|  | 000001 | **Hitos** |  |  | 2024-06-13 | 2025-11-17 |  |  |  |  |  |  |  |  |  |  |  |  |  |  |  |
| 000002 |  | Inicio/Acceso | milestone | 0d | 2024-06-13 | 2024-06-13 |  | 0d |  |  | 1.1 | 206 | Cronograma Gantt_13 | 2024-06-13 | 2024-06-13 | 2024-06-13 | 2024-06-12 | 2024-06-13 | 2024-06-13 | 2 | 2 |
| 000003 |  | Inicio Obras Provisionales | milestone | 0d | 2024-06-13 | 2024-06-13 | 000002 | 0d |  |  | 1.2 | 205 | Cronograma Gantt_13 | 2024-06-14 | 2024-06-13 | 2024-06-13 | 2024-06-13 | 2024-06-13 | 2024-06-13 | 3 | 3 |
| 000005 |  | Inicio DI-PR-55-D | milestone | 0d | 2024-07-26 | 2024-07-26 | 000030 | 0d |  |  | 1.4 | 1262 | Cronograma Gantt_13 | 2024-07-27 | 2024-07-26 | 2024-07-26 | 2024-07-26 | 2024-07-26 | 2024-07-26 | 5 | 5 |
| 000009 |  | Inicio DI-PR-42-0-I | milestone | 0d | 2024-07-26 | 2024-07-26 | 000030 | 289d | 0d |  | 1.8 | 1265 | Cronograma Gantt_13 | 2024-08-31 | 2025-09-08 | 2024-08-30 | 2024-08-30 | 2025-09-08 | 2024-08-30 | 9 | 9 |
| 000163 |  | Inicio Obras - Primera Etapa | milestone | 0d | 2024-07-26 | 2024-07-26 | 000030 | 360d |  |  |  |  |  |  |  |  |  |  |  |  |  |
| 000011 |  | Inicio DI-PR-42-5-I | milestone | 0d | 2024-07-29 | 2024-07-29 | 000151 | 314d | 0d |  | 1.10 | 1268 | Cronograma Gantt_13 | 2024-09-03 | 2025-10-06 | 2024-09-02 | 2024-09-02 | 2025-10-06 | 2024-09-02 | 11 | 11 |
| 000007 |  | Inicio DI-PR-47-D | milestone | 0d | 2024-08-27 | 2024-08-27 | 000045 | 0d |  |  | 1.6 | 1267 | Cronograma Gantt_13 | 2024-08-27 | 2024-08-27 | 2024-08-26 | 2024-08-26 | 2024-08-27 | 2024-08-26 | 7 | 7 |
| 000012 |  | Fin DI-PR-42-5-I | milestone | 0d | 2024-09-09 | 2024-09-09 | 000209, 000208, 000206, 000183, 000179, 000178 | 314d |  |  | 1.11 | 1269 | Cronograma Gantt_13 | 2024-10-16 | 2025-11-17 | 2024-10-15 | 2024-10-15 | 2025-11-17 | 2024-10-15 | 12 | 12 |
| 000010 |  | Fin DI-PR-42-0-I | milestone | 0d | 2024-10-04 | 2024-10-04 | 000171, 000157, 000154, 000153 | 289d |  |  | 1.9 | 1264 | Cronograma Gantt_13 | 2024-11-10 | 2025-11-17 | 2024-11-09 | 2024-11-09 | 2025-11-17 | 2024-11-09 | 10 | 10 |
| 000006 |  | Fin DI-PR-55-D | milestone | 0d | 2024-11-21 | 2024-11-21 | 000083, 000072, 000060, 000054, 000052, 000049, 000048 | 241d |  | start on or after 2024-11-22 | 1.5 | 1263 | Cronograma Gantt_13 | 2024-11-23 | 2025-11-17 | 2024-11-22 | 2024-11-22 | 2025-11-17 | 2024-11-22 | 6 | 6 |
| 000008 |  | Fin DI-PR-47-D | milestone | 0d | 2024-12-31 | 2024-12-31 | 000146, 000144, 000143, 000142, 000140, 000139, 000136, 000130, 000123, 000107, 000100, 000097, 000094, 000093, 000092 | 201d | 0d | start on or after 2024-12-31 | 1.7 | 1266 | Cronograma Gantt_13 | 2025-01-01 | 2025-11-17 | 2024-12-31 | 2024-12-31 | 2025-11-17 | 2024-12-31 | 8 | 8 |
| 000013 |  | Fin - Primera Etapa | milestone | 0d | 2024-12-31 | 2024-12-31 | 000008 | 201d |  |  | 1.12 | 1303 | Cronograma Gantt_13 | 2025-01-01 | 2025-11-17 | 2024-12-31 | 2024-12-31 | 2025-11-17 | 2024-12-31 | 13 | 13 |
| 000015 |  | Inicio DI-PR-53-I | milestone | 0d | 2025-05-01 | 2025-05-01 | 000084 SS | 201d |  |  | 1.14 | 1278 | Cronograma Gantt_13 | 2025-05-02 | 2025-11-17 | 2025-05-01 | 2025-05-01 | 2025-11-17 | 2025-05-01 | 15 | 15 |
| 000084 |  | Inicio Segunda Etapa | milestone | 0d | 2025-05-01 | 2025-05-01 | 000008 | 201d | 0d |  |  |  |  |  |  |  |  |  |  |  |  |
| 000017 |  | Inicio DI-PR-51-I | milestone | 0d | 2025-05-26 | 2025-05-26 | 000217 | 0d |  |  | 1.16 | 1280 | Cronograma Gantt_13 | 2025-05-26 | 2025-05-26 | 2025-05-25 | 2025-05-25 | 2025-05-26 | 2025-05-25 | 17 | 17 |
| 000019 |  | Inicio DI-PR-47bis-D / DE-PR-49bis-D | milestone | 0d | 2025-06-19 | 2025-06-19 | 000278 | 0d |  |  | 1.18 | 1282 | Cronograma Gantt_13 | 2025-06-19 | 2025-06-19 | 2025-06-18 | 2025-06-18 | 2025-06-19 | 2025-06-18 | 19 | 19 |
| 000021 |  | Inicio DI-PR-40A-D / DI-PR-40B-D | milestone | 0d | 2025-07-09 | 2025-07-09 | 000332 | 2d | 0d |  | 1.20 | 1287 | Cronograma Gantt_13 | 2025-07-09 | 2025-07-11 | 2025-07-08 | 2025-07-08 | 2025-07-11 | 2025-07-08 | 21 | 21 |
| 000023 |  | Inicio DI-PR-42-1-I / DI-PR-42-3-I | milestone | 0d | 2025-08-04 | 2025-08-04 | 000372 | 2d | 0d |  | 1.22 | 1289 | Cronograma Gantt_13 | 2025-08-04 | 2025-08-06 | 2025-08-03 | 2025-08-03 | 2025-08-06 | 2025-08-03 | 23 | 23 |
| 000025 |  | Inicio DE-PR-39-I | milestone | 0d | 2025-08-08 | 2025-08-08 | 000416 | 6d | 0d |  | 1.24 | 1293 | Cronograma Gantt_13 | 2025-08-08 | 2025-08-14 | 2025-08-07 | 2025-08-07 | 2025-08-14 | 2025-08-07 | 25 | 25 |
| 000016 |  | Fin DI-PR-53-I | milestone | 0d | 2025-08-09 | 2025-08-09 | 000270, 000269, 000265, 000262, 000258, 000252, 000251, 000235, 000234, 000228, 000225, 000224, 000222, 000221, 000220, 000219, 000218 | 100d |  |  | 1.15 | 1279 | Cronograma Gantt_13 | 2025-08-10 | 2025-11-17 | 2025-08-09 | 2025-08-09 | 2025-11-17 | 2025-08-09 | 16 | 16 |
| 000018 |  | Fin DI-PR-51-I | milestone | 0d | 2025-10-09 | 2025-10-09 | 000325, 000324, 000323, 000322, 000321, 000319, 000314, 000309, 000308, 000292, 000282, 000281, 000280, 000279 | 39d |  |  | 1.17 | 1281 | Cronograma Gantt_13 | 2025-10-10 | 2025-11-17 | 2025-10-09 | 2025-10-09 | 2025-11-17 | 2025-10-09 | 18 | 18 |
| 000022 |  | Fin DI-PR-40A-D / DI-PR-40B-D | milestone | 0d | 2025-10-24 | 2025-10-24 | 000411, 000393, 000390, 000389, 000382, 000379, 000378, 000376, 000375, 000373 | 24d |  |  | 1.21 | 1290 | Cronograma Gantt_13 | 2025-10-25 | 2025-11-17 | 2025-10-24 | 2025-10-24 | 2025-11-17 | 2025-10-24 | 22 | 22 |
| 000020 |  | Fin DI-PR-47bis-D / DE-PR-49bis-D | milestone | 0d | 2025-10-31 | 2025-10-31 | 000352, 000351, 000345, 000344, 000342, 000341, 000337, 000336, 000335, 000334 | 17d |  |  | 1.19 | 1288 | Cronograma Gantt_13 | 2025-11-01 | 2025-11-17 | 2025-10-31 | 2025-10-31 | 2025-11-17 | 2025-10-31 | 20 | 20 |
| 000026 |  | Fin Inicio DE-PR-39-I | milestone | 0d | 2025-11-11 | 2025-11-11 | 000518, 000517, 000514, 000512, 000511, 000508, 000503, 000480, 000479, 000472, 000471, 000468, 000465, 000464, 000463, 000462 | 6d |  |  | 1.25 | 1295 | Cronograma Gantt_13 | 2025-11-12 | 2025-11-17 | 2025-11-11 | 2025-11-11 | 2025-11-17 | 2025-11-11 | 26 | 26 |
| 000024 |  | Fin DI-PR-42-1-I / DI-PR-42-3-I | milestone | 0d | 2025-11-15 | 2025-11-15 | 000453, 000436, 000435, 000434, 000433, 000429, 000422, 000421, 000420 | 2d |  |  | 1.23 | 1292 | Cronograma Gantt_13 | 2025-11-16 | 2025-11-17 | 2025-11-15 | 2025-11-15 | 2025-11-17 | 2025-11-15 | 24 | 24 |
| 000027 |  | Fin Segunda Etapa | milestone | 0d | 2025-11-17 | 2025-11-17 | 000026, 000024, 000022, 000020, 000018, 000016, 000015, 000338 FF | 0d |  | start on or after 2025-11-17 | 1.26 | 1296 | Cronograma Gantt_13 | 2025-11-18 | 2025-11-17 | 2025-11-17 | 2025-11-17 | 2025-11-17 | 2025-11-17 | 27 | 27 |
| 000028 |  | Culminación de Obra | milestone | 0d | 2025-11-17 | 2025-11-17 | 000027 | 0d |  | start on or after 2025-11-17 | 1.27 | 1300 | Cronograma Gantt_13 | 2025-11-18 | 2025-11-17 | 2025-11-17 | 2025-11-17 | 2025-11-17 | 2025-11-17 | 28 | 28 |

| ID | WBS | Activity | Duration | Start | Finish | Predecessors | Total float | Free float | MSP Outline Number | MSP Unique ID | MSP Project Name | Imported Early Start | Imported Late Start | Imported Start | Imported Early Finish | Imported Late Finish | Imported Finish | MSP ID | MSP Task Order |
| --- | --- | --- | --- | --- | --- | --- | --- | --- | --- | --- | --- | --- | --- | --- | --- | --- | --- | --- | --- |
|  | 000029 | **Obras Provisionales** |  | 2024-06-13 | 2024-07-25 |  |  |  |  |  |  |  |  |  |  |  |  |  |  |
| 000030 |  | Campamento Provisional de Obra | 43d | 2024-06-13 | 2024-07-25 | 000003 | 0d |  | 2.1 | 95 | Cronograma Gantt_13 | 2024-06-13 | 2024-06-13 | 2024-06-13 | 2024-07-24 | 2024-07-24 | 2024-07-24 | 30 | 30 |
| 000031 |  | Movilizacion y Desmovilizacion de Maquinaria Pesada | 41d | 2024-06-13 | 2024-07-23 | 000003 | 362d |  | 2.2 | 96 | Cronograma Gantt_13 | 2024-06-13 | 2024-06-15 | 2024-06-13 | 2024-07-23 | 2024-07-25 | 2024-07-23 | 31 | 31 |
| 000032 |  | Mejoramiento y Habilitacion de Caminos de Acceso | 21d | 2024-06-13 | 2024-07-03 | 000003 | 361d | 0d | 2.3 | 97 | Cronograma Gantt_13 | 2024-06-13 | 2024-06-14 | 2024-06-13 | 2024-07-03 | 2024-07-04 | 2024-07-03 | 32 | 32 |
| 000033 |  | Limpieza Manual de Material Vegetal y de Residuos | 42d | 2024-06-13 | 2024-07-24 | 000003 | 361d |  | 2.4 | 98 | Cronograma Gantt_13 | 2024-06-13 | 2024-06-14 | 2024-06-13 | 2024-07-24 | 2024-07-25 | 2024-07-24 | 33 | 33 |
| 000034 |  | Mantenimiento de Caminos de Acceso | 21d | 2024-07-04 | 2024-07-24 | 000032 | 361d |  | 2.5 | 99 | Cronograma Gantt_13 | 2024-07-04 | 2024-07-05 | 2024-07-04 | 2024-07-24 | 2024-07-25 | 2024-07-24 | 34 | 34 |
| 000035 |  | Habilitacion de Plataformas | 21d | 2024-07-04 | 2024-07-24 | 000032 | 361d |  | 2.6 | 100 | Cronograma Gantt_13 | 2024-07-04 | 2024-07-05 | 2024-07-04 | 2024-07-24 | 2024-07-25 | 2024-07-24 | 35 | 35 |
| 000036 |  | Tuberia HDPE Corrugada f=600mm, para Caminos de Acceso (o similar) | 21d | 2024-07-04 | 2024-07-24 | 000032 | 361d |  | 2.7 | 101 | Cronograma Gantt_13 | 2024-07-04 | 2024-07-05 | 2024-07-04 | 2024-07-24 | 2024-07-25 | 2024-07-24 | 36 | 36 |
| 000037 |  | Tuberia HDPE Corrugada f=1000mm, para Caminos de Acceso (o similar) | 21d | 2024-07-04 | 2024-07-24 | 000032 | 361d |  | 2.8 | 102 | Cronograma Gantt_13 | 2024-07-04 | 2024-07-05 | 2024-07-04 | 2024-07-24 | 2024-07-25 | 2024-07-24 | 37 | 37 |
|  | 000038 | **Topografia** |  | 2024-06-18 | 2024-07-02 |  |  |  |  |  |  |  |  |  |  |  |  |  |  |
| 000039 |  | Trazo y Replanteo Inicial | 15d | 2024-06-18 | 2024-07-02 | 000030 SS+5d | 383d |  | 3.1 | 106 | Cronograma Gantt_13 | 2024-06-18 | 2024-06-18 | 2024-06-18 | 2024-07-25 | 2024-07-25 | 2024-07-25 | 39 | 39 |
|  | 000040 | **PRIMERA ETAPA** |  | 2024-07-26 | 2024-12-31 |  |  |  |  |  |  |  |  |  |  |  |  |  |  |
|  | 000041 | **DI-PR-55-D** |  | 2024-07-26 | 2024-11-21 |  |  |  |  |  |  |  |  |  |  |  |  |  |  |
|  | 000042 | **Excavaciones** |  | 2024-07-28 | 2024-09-30 |  |  |  |  |  |  |  |  |  |  |  |  |  |  |
| 000043 |  | Desbroce | 1d | 2024-07-28 | 2024-07-28 | 000085 | 0d |  | 4.1.1.1 | 108 | Cronograma Gantt_13 | 2024-07-28 | 2024-07-28 | 2024-07-28 | 2024-07-28 | 2024-07-28 | 2024-07-28 | 43 | 43 |
| 000044 |  | Remocion de Dique Existente | 11d | 2024-07-29 | 2024-08-08 | 000043 | 0d |  | 4.1.1.2 | 109 | Cronograma Gantt_13 | 2024-07-29 | 2024-07-29 | 2024-07-29 | 2024-08-08 | 2024-08-08 | 2024-08-08 | 44 | 44 |
| 000049 |  | Conformacion de Material Excedente en DMO | 6d | 2024-07-30 | 2024-08-04 | 000064 SS+1d | 350d | 109d | 4.1.1.7 | 114 | Cronograma Gantt_13 | 2024-07-30 | 2025-11-12 | 2024-07-30 | 2024-08-04 | 2025-11-17 | 2024-08-04 | 49 | 49 |
| 000045 |  | Excavacion de Cimentacion | 18d | 2024-08-09 | 2024-08-26 | 000044 | 0d |  | 4.1.1.3 | 110 | Cronograma Gantt_13 | 2024-08-09 | 2024-08-09 | 2024-08-09 | 2024-08-26 | 2024-08-26 | 2024-08-26 | 45 | 45 |
| 000046 |  | Perfilado y Conformacion de Plataforma de Fundacion | 9d | 2024-08-11 | 2024-08-19 | 000045 SS+2d | 241d | 0d | 4.1.1.4 | 111 | Cronograma Gantt_13 | 2024-08-11 | 2025-08-07 | 2024-08-11 | 2024-08-19 | 2025-08-15 | 2024-08-19 | 46 | 46 |
| 000047 |  | Excavacion de Uña | 19d | 2024-08-11 | 2024-08-29 | 000045 SS+2d | 283d | 42d | 4.1.1.5 | 112 | Cronograma Gantt_13 | 2024-08-11 | 2025-09-18 | 2024-08-11 | 2024-08-29 | 2025-10-06 | 2024-08-29 | 47 | 47 |
| 000048 |  | Conformacion de Material Excedente en DME | 39d | 2024-08-23 | 2024-09-30 | 000066 SS+1d | 293d | 52d | 4.1.1.6 | 113 | Cronograma Gantt_13 | 2024-08-23 | 2025-10-10 | 2024-08-23 | 2024-09-30 | 2025-11-17 | 2024-09-30 | 48 | 48 |
|  | 000050 | **Rellenos** |  | 2024-08-20 | 2024-10-17 |  |  |  |  |  |  |  |  |  |  |  |  |  |  |
| 000051 |  | Relleno con Material Granular (incluye extraccion de material, zarandeo y combinado) | 27d | 2024-08-20 | 2024-09-15 | 000046 | 241d | 0d | 4.1.2.1 | 118 | Cronograma Gantt_13 | 2024-08-20 | 2025-08-16 | 2024-08-20 | 2024-09-15 | 2025-09-11 | 2024-09-15 | 51 | 51 |
| 000053 |  | Perfilado de Talud Dique | 13d | 2024-09-16 | 2024-09-28 | 000051 | 241d | 0d | 4.1.2.3 | 121 | Cronograma Gantt_13 | 2024-09-16 | 2025-09-12 | 2024-09-16 | 2024-09-28 | 2025-09-24 | 2024-09-28 | 53 | 53 |
| 000054 |  | Grava para Drenaje | 1d | 2024-09-29 | 2024-09-29 | 000053 | 294d | 53d | 4.1.2.4 | 123 | Cronograma Gantt_13 | 2024-09-29 | 2025-11-17 | 2024-09-29 | 2024-09-29 | 2025-11-17 | 2024-09-29 | 54 | 54 |
| 000052 |  | Relleno Afirmado | 1d | 2024-10-17 | 2024-10-17 | 000068, 000057 | 276d | 35d | 4.1.2.2 | 120 | Cronograma Gantt_13 | 2024-10-17 | 2025-11-17 | 2024-10-17 | 2024-10-17 | 2025-11-17 | 2024-10-17 | 52 | 52 |

| ID | WBS | Activity | Duration | Start | Finish | Predecessors | Total float | Free float | MSP Outline Number | MSP Unique ID | MSP Project Name | Imported Early Start | Imported Late Start | Imported Start | Imported Early Finish | Imported Late Finish | Imported Finish | MSP ID | MSP Task Order |
| --- | --- | --- | --- | --- | --- | --- | --- | --- | --- | --- | --- | --- | --- | --- | --- | --- | --- | --- | --- |
|  | 000055 | **Geotextil** |  | 2024-09-29 | 2024-10-16 |  |  |  |  |  |  |  |  |  |  |  |  |  |  |
| 000056 |  | Instalacion de Geotextil 400gr/m2 | 12d | 2024-09-29 | 2024-10-10 | 000074, 000053 | 241d | 0d | 4.1.3.1 | 126 | Cronograma Gantt_13 | 2024-09-29 | 2025-09-25 | 2024-09-29 | 2024-10-10 | 2025-10-06 | 2024-10-10 | 56 | 56 |
| 000057 |  | Zanja de Anclaje | 6d | 2024-10-11 | 2024-10-16 | 000056 | 276d | 0d | 4.1.3.2 | 127 | Cronograma Gantt_13 | 2024-10-11 | 2025-11-11 | 2024-10-11 | 2024-10-16 | 2025-11-16 | 2024-10-16 | 57 | 57 |
|  | 000058 | **Colocacion de Roca** |  | 2024-08-09 | 2024-11-21 |  |  |  |  |  |  |  |  |  |  |  |  |  |  |
| 000061 |  | Extraccion de Rocas Reutilizables | 14d | 2024-08-09 | 2024-08-22 | 000044 | 307d | 66d | 4.1.4.3 | 132 | Cronograma Gantt_13 | 2024-08-09 | 2025-10-10 | 2024-08-09 | 2024-08-22 | 2025-10-23 | 2024-08-22 | 61 | 61 |
| 000059 |  | Colocacion de Roca en Uña | 17d | 2024-10-11 | 2024-10-27 | 000056, 000047 | 241d | 0d | 4.1.4.1 | 130 | Cronograma Gantt_13 | 2024-10-11 | 2025-10-07 | 2024-10-11 | 2024-10-27 | 2025-10-23 | 2024-10-27 | 59 | 59 |
| 000060 |  | Colocacion de Roca en Talud | 25d | 2024-10-28 | 2024-11-21 | 000061, 000059 | 241d | 0d | 4.1.4.2 | 131 | Cronograma Gantt_13 | 2024-10-28 | 2025-10-24 | 2024-10-28 | 2024-11-21 | 2025-11-17 | 2024-11-21 | 60 | 60 |
|  | 000062 | **Transportes** |  | 2024-07-29 | 2024-10-10 |  |  |  |  |  |  |  |  |  |  |  |  |  |  |
| 000063 |  | Transporte de Material Organico (a DMO) D<=1km | 24d | 2024-07-29 | 2024-08-21 | 000043 SS+1d | 307d | 0d | 4.1.5.1 | 141 | Cronograma Gantt_13 | 2024-07-29 | 2025-09-29 | 2024-07-29 | 2024-08-21 | 2025-10-22 | 2024-08-21 | 63 | 63 |
| 000064 |  | Transporte de Material Organico (a DMO) D>1km | 35d | 2024-07-29 | 2024-09-01 | 000063 SS | 307d | 0d | 4.1.5.2 | 142 | Cronograma Gantt_13 | 2024-07-29 | 2025-09-29 | 2024-07-29 | 2024-09-01 | 2025-11-02 | 2024-09-01 | 64 | 64 |
| 000065 |  | Transporte de Material Excedente D<=1km | 40d | 2024-07-30 | 2024-09-07 | 000044 SS+1d | 282d | 0d | 4.1.5.3 | 143 | Cronograma Gantt_13 | 2024-07-30 | 2025-09-05 | 2024-07-30 | 2024-09-07 | 2025-10-14 | 2024-09-07 | 65 | 65 |
| 000066 |  | Transporte de Material Excedente D>1km | 18d | 2024-08-22 | 2024-09-08 | 000065 FS-17d | 282d | 0d | 4.1.5.4 | 144 | Cronograma Gantt_13 | 2024-08-22 | 2025-09-28 | 2024-08-22 | 2024-09-08 | 2025-10-15 | 2024-09-08 | 66 | 66 |
| 000069 |  | Transporte de Roca D<=1km | 28d | 2024-09-01 | 2024-09-28 | 000053 FF | 253d | 0d | 4.1.5.7 | 147 | Cronograma Gantt_13 | 2024-09-01 | 2025-09-09 | 2024-09-01 | 2024-09-28 | 2025-10-06 | 2024-09-28 | 69 | 69 |
| 000070 |  | Transporte de Roca D>1km | 15d | 2024-09-01 | 2024-09-15 | 000069 SS | 253d | 0d | 4.1.5.8 | 148 | Cronograma Gantt_13 | 2024-09-01 | 2025-09-09 | 2024-09-01 | 2024-09-15 | 2025-09-23 | 2024-09-15 | 70 | 70 |
| 000071 |  | Transporte de Material de Prestamo Cantera de Rio (Cuerpo de Terraplen) D<=1km | 15d | 2024-09-02 | 2024-09-16 | 000064 | 307d | 0d | 4.1.5.9 | 149 | Cronograma Gantt_13 | 2024-09-02 | 2025-11-03 | 2024-09-02 | 2024-09-16 | 2025-11-17 | 2024-09-16 | 71 | 71 |
| 000072 |  | Transporte de Material de Prestamo Cantera de Rio (Cuerpo de Terraplen) D>1km | 10d | 2024-09-02 | 2024-09-11 | 000071 SS | 312d | 71d | 4.1.5.10 | 150 | Cronograma Gantt_13 | 2024-09-02 | 2025-11-08 | 2024-09-02 | 2024-09-11 | 2025-11-17 | 2024-09-11 | 72 | 72 |
| 000067 |  | Transporte de Material de Prestamo (Afirmado) D<=1km | 24d | 2024-09-09 | 2024-10-02 | 000066 | 282d | 0d | 4.1.5.5 | 145 | Cronograma Gantt_13 | 2024-09-09 | 2025-10-16 | 2024-09-09 | 2024-10-02 | 2025-11-08 | 2024-10-02 | 67 | 67 |
| 000068 |  | Transporte de Material de Prestamo (Afirmado) D>1km | 32d | 2024-09-09 | 2024-10-10 | 000067 SS | 282d | 6d | 4.1.5.6 | 146 | Cronograma Gantt_13 | 2024-09-09 | 2025-10-16 | 2024-09-09 | 2024-10-10 | 2025-11-16 | 2024-10-10 | 68 | 68 |
| 000073 |  | Transporte de Material Seleccionado para Zanja D<=1km | 1d | 2024-09-16 | 2024-09-16 | 000070 | 253d | 0d | 4.1.5.11 | 151 | Cronograma Gantt_13 | 2024-09-16 | 2025-09-24 | 2024-09-16 | 2024-09-16 | 2025-09-24 | 2024-09-16 | 73 | 73 |
| 000074 |  | Transporte de Material Seleccionado para Zanja D>1km | 1d | 2024-09-16 | 2024-09-16 | 000073 SS | 253d | 12d | 4.1.5.12 | 152 | Cronograma Gantt_13 | 2024-09-16 | 2025-09-24 | 2024-09-16 | 2024-09-16 | 2025-09-24 | 2024-09-16 | 74 | 74 |
|  | 000075 | **Obras Civiles** |  | 2024-08-27 | 2024-09-20 |  |  |  |  |  |  |  |  |  |  |  |  |  |  |
| 000076 |  | Concreto de Nivelacion (f'c=100 kg/cm2) | 1d | 2024-08-27 | 2024-08-27 | 000045 | 303d | 0d | 4.1.6.1 | 188 | Cronograma Gantt_13 | 2024-08-27 | 2025-10-24 | 2024-08-27 | 2024-08-27 | 2025-10-24 | 2024-08-27 | 76 | 76 |
| 000081 |  | Acero de refuerzo f'y=4200kg/cm2 | 6d | 2024-08-28 | 2024-09-02 | 000076 | 303d | 0d | 4.1.6.6 | 193 | Cronograma Gantt_13 | 2024-08-28 | 2025-10-25 | 2024-08-28 | 2024-09-02 | 2025-10-30 | 2024-09-02 | 81 | 81 |
| 000077 |  | Concreto Clase C (f'c=280 kg/cm2) Premezclado - Cimientos reforzados | 1d | 2024-08-30 | 2024-08-30 | 000081 SS+2d | 303d | 0d | 4.1.6.2 | 189 | Cronograma Gantt_13 | 2024-08-30 | 2025-10-27 | 2024-08-30 | 2024-08-30 | 2025-10-27 | 2024-08-30 | 77 | 77 |
| 000080 |  | Encofrado y Desencofrado Cara Oculta | 2d | 2024-09-04 | 2024-09-05 | 000077 FS+4d | 318d |  | 4.1.6.5 | 192 | Cronograma Gantt_13 | 2024-09-04 | 2025-11-16 | 2024-09-04 | 2024-09-05 | 2025-11-17 | 2024-09-05 | 80 | 80 |
| 000079 |  | Encofrado y Desencofrado Caravista | 8d | 2024-09-05 | 2024-09-12 | 000077 FS+5d | 303d | 0d | 4.1.6.4 | 191 | Cronograma Gantt_13 | 2024-09-05 | 2025-11-02 | 2024-09-05 | 2024-09-12 | 2025-11-09 | 2024-09-12 | 79 | 79 |
| 000078 |  | Concreto Clase C (f'c=280 kg/cm2) Premezclado - Muros de contencion | 1d | 2024-09-13 | 2024-09-13 | 000079 | 303d | 0d | 4.1.6.3 | 190 | Cronograma Gantt_13 | 2024-09-13 | 2025-11-10 | 2024-09-13 | 2024-09-13 | 2025-11-10 | 2024-09-13 | 78 | 78 |
| 000082 |  | Junta de dilatación | 1d | 2024-09-14 | 2024-09-14 | 000078 | 303d | 0d | 4.1.6.7 | 194 | Cronograma Gantt_13 | 2024-09-14 | 2025-11-11 | 2024-09-14 | 2024-09-14 | 2025-11-11 | 2024-09-14 | 82 | 82 |
| 000083 |  | Pintura bituminosa | 6d | 2024-09-15 | 2024-09-20 | 000082 | 303d | 62d | 4.1.6.8 | 195 | Cronograma Gantt_13 | 2024-09-15 | 2025-11-12 | 2024-09-15 | 2024-09-20 | 2025-11-17 | 2024-09-20 | 83 | 83 |

| ID | WBS | Activity | Duration | Start | Finish | Predecessors | Total float | Free float | MSP Outline Number | MSP Unique ID | MSP Project Name | Imported Early Start | Imported Late Start | Imported Start | Imported Early Finish | Imported Late Finish | Imported Finish | MSP ID | MSP Task Order |
| --- | --- | --- | --- | --- | --- | --- | --- | --- | --- | --- | --- | --- | --- | --- | --- | --- | --- | --- | --- |
|  | 000084 | **Mitigación Ambiental** |  | 2024-07-26 | 2024-07-27 |  |  |  |  |  |  |  |  |  |  |  |  |  |  |
| 000085 |  | Rescate camaron | 2d | 2024-07-26 | 2024-07-27 | 000005 | 0d |  | 4.1.7.1 | 1322 | Cronograma Gantt_13 | 2024-07-26 | 2024-07-26 | 2024-07-26 | 2024-07-27 | 2024-07-27 | 2024-07-27 | 85 | 85 |
|  | 000086 | **DI-PR-47-D** |  | 2024-08-27 | 2024-12-31 |  |  |  |  |  |  |  |  |  |  |  |  |  |  |
|  | 000087 | **Excavaciones** |  | 2024-08-29 | 2024-10-17 |  |  |  |  |  |  |  |  |  |  |  |  |  |  |
| 000088 |  | Desbroce | 2d | 2024-08-29 | 2024-08-30 | 000148 | 0d |  | 4.2.1.1 | 214 | Cronograma Gantt_13 | 2024-08-29 | 2024-08-29 | 2024-08-29 | 2024-08-30 | 2024-08-30 | 2024-08-30 | 88 | 88 |
| 000089 |  | Excavacion de Cimentacion | 12d | 2024-08-29 | 2024-09-09 | 000088 FS-2d | 0d |  | 4.2.1.2 | 216 | Cronograma Gantt_13 | 2024-08-29 | 2024-08-29 | 2024-08-29 | 2024-09-09 | 2024-09-09 | 2024-09-09 | 89 | 89 |
| 000090 |  | Perfilado y Conformacion de Plataforma de Fundacion | 16d | 2024-08-31 | 2024-09-15 | 000089 SS+2d | 17d | 0d | 4.2.1.3 | 217 | Cronograma Gantt_13 | 2024-08-31 | 2024-09-17 | 2024-08-31 | 2024-09-15 | 2024-10-02 | 2024-09-15 | 90 | 90 |
| 000091 |  | Excavacion de Uña | 40d | 2024-08-31 | 2024-10-09 | 000089 SS+2d | 0d |  | 4.2.1.4 | 218 | Cronograma Gantt_13 | 2024-08-31 | 2024-08-31 | 2024-08-31 | 2024-10-09 | 2024-10-09 | 2024-10-09 | 91 | 91 |
| 000092 |  | Conformacion de Material Excedente en DME | 48d | 2024-08-31 | 2024-10-17 | 000112 SS+1d | 276d | 75d | 4.2.1.5 | 219 | Cronograma Gantt_13 | 2024-08-31 | 2025-10-01 | 2024-08-31 | 2024-10-17 | 2025-11-17 | 2024-10-17 | 92 | 92 |
| 000093 |  | Conformacion de Material Excedente en DMO | 7d | 2024-08-31 | 2024-09-06 | 000110 SS+1d | 317d | 116d | 4.2.1.6 | 220 | Cronograma Gantt_13 | 2024-08-31 | 2025-11-11 | 2024-08-31 | 2024-09-06 | 2025-11-17 | 2024-09-06 | 93 | 93 |
| 000094 |  | Excavacion Localizada - Sobreexcavacion | 25d | 2024-09-04 | 2024-09-28 | 000089 SS+6d | 295d | 94d | 4.2.1.7 | 221 | Cronograma Gantt_13 | 2024-09-04 | 2025-10-24 | 2024-09-04 | 2024-09-28 | 2025-11-17 | 2024-09-28 | 94 | 94 |
|  | 000095 | **Rellenos** |  | 2024-09-04 | 2024-12-08 |  |  |  |  |  |  |  |  |  |  |  |  |  |  |
| 000096 |  | Relleno con Material Granular (incluye extraccion de material, zarandeo y combinado) | 20d | 2024-09-04 | 2024-09-23 | 000090 SS+4d | 17d | 0d | 4.2.2.1 | 224 | Cronograma Gantt_13 | 2024-09-04 | 2024-09-21 | 2024-09-04 | 2024-09-23 | 2024-10-10 | 2024-09-23 | 96 | 96 |
| 000100 |  | Relleno con Material Seleccionado (incluye extraccion de material, zarandeo y combinado) | 13d | 2024-09-06 | 2024-09-18 | 000096 SS+2d | 305d | 104d | 4.2.2.5 | 228 | Cronograma Gantt_13 | 2024-09-06 | 2025-11-05 | 2024-09-06 | 2024-09-18 | 2025-11-17 | 2024-09-18 | 100 | 100 |
| 000099 |  | Perfilado de Talud Dique | 7d | 2024-09-14 | 2024-09-20 | 000096 SS+10d | 17d | 0d | 4.2.2.4 | 227 | Cronograma Gantt_13 | 2024-09-14 | 2024-10-01 | 2024-09-14 | 2024-09-20 | 2024-10-07 | 2024-09-20 | 99 | 99 |
| 000101 |  | Grava para Drenaje | 2d | 2024-09-21 | 2024-09-22 | 000099 | 301d |  | 4.2.2.6 | 229 | Cronograma Gantt_13 | 2024-09-21 | 2025-11-16 | 2024-09-21 | 2024-09-22 | 2025-11-17 | 2024-09-22 | 101 | 101 |
| 000098 |  | Relleno Afirmado | 2d | 2024-11-21 | 2024-11-22 | 000114, 000104 | 0d |  | 4.2.2.3 | 226 | Cronograma Gantt_13 | 2024-11-21 | 2024-11-21 | 2024-11-21 | 2024-11-22 | 2024-11-22 | 2024-11-22 | 98 | 98 |
| 000097 |  | Relleno sin Compactar | 4d | 2024-12-05 | 2024-12-08 | 000106 | 224d | 23d | 4.2.2.2 | 225 | Cronograma Gantt_13 | 2024-12-05 | 2025-11-14 | 2024-12-05 | 2024-12-08 | 2025-11-17 | 2024-12-08 | 97 | 97 |
|  | 000102 | **Geotextil** |  | 2024-10-10 | 2024-11-08 |  |  |  |  |  |  |  |  |  |  |  |  |  |  |
| 000103 |  | Instalacion de Geotextil 400gr/m2 | 15d | 2024-10-10 | 2024-10-24 | 000091 | 0d |  | 4.2.3.1 | 232 | Cronograma Gantt_13 | 2024-10-10 | 2024-10-10 | 2024-10-10 | 2024-10-24 | 2024-10-24 | 2024-10-24 | 103 | 103 |
| 000104 |  | Zanja de Anclaje | 15d | 2024-10-25 | 2024-11-08 | 000120, 000103 | 0d |  | 4.2.3.2 | 233 | Cronograma Gantt_13 | 2024-10-25 | 2024-10-25 | 2024-10-25 | 2024-11-08 | 2024-11-08 | 2024-11-08 | 104 | 104 |
|  | 000105 | **Colocacion de Roca** |  | 2024-11-23 | 2024-12-31 |  |  |  |  |  |  |  |  |  |  |  |  |  |  |
| 000106 |  | Colocacion de Roca en Uña | 12d | 2024-11-23 | 2024-12-04 | 000116, 000098 | 0d |  | 4.2.4.1 | 236 | Cronograma Gantt_13 | 2024-11-23 | 2024-11-23 | 2024-11-23 | 2024-12-04 | 2024-12-04 | 2024-12-04 | 106 | 106 |
| 000107 |  | Colocacion de Roca en Talud | 29d | 2024-12-03 | 2024-12-31 | 000106 SS+10d | 0d |  | 4.2.4.2 | 237 | Cronograma Gantt_13 | 2024-12-03 | 2024-12-03 | 2024-12-03 | 2024-12-31 | 2024-12-31 | 2024-12-31 | 107 | 107 |

| ID | WBS | Activity | Duration | Start | Finish | Predecessors | Total float | Free float | MSP Outline Number | MSP Unique ID | MSP Project Name | Imported Early Start | Imported Late Start | Imported Start | Imported Early Finish | Imported Late Finish | Imported Finish | MSP ID | MSP Task Order |
| --- | --- | --- | --- | --- | --- | --- | --- | --- | --- | --- | --- | --- | --- | --- | --- | --- | --- | --- | --- |
|  | 000108 | **Transportes** |  | 2024-08-30 | 2024-11-20 |  |  |  |  |  |  |  |  |  |  |  |  |  |  |
| 000109 |  | Transporte de Material Organico (a DMO) D<=1km | 14d | 2024-08-30 | 2024-09-12 | 000088 SS+1d | 304d | 0d | 4.2.5.1 | 247 | Cronograma Gantt_13 | 2024-08-30 | 2025-10-28 | 2024-08-30 | 2024-09-12 | 2025-11-10 | 2024-09-12 | 109 | 109 |
| 000110 |  | Transporte de Material Organico (a DMO) D>1km | 21d | 2024-08-30 | 2024-09-19 | 000109 SS | 304d | 0d | 4.2.5.2 | 248 | Cronograma Gantt_13 | 2024-08-30 | 2025-10-28 | 2024-08-30 | 2024-09-19 | 2025-11-17 | 2024-09-19 | 110 | 110 |
| 000111 |  | Transporte de Material Excedente D<=1km | 49d | 2024-08-30 | 2024-10-17 | 000089 SS+1d | 242d | 0d | 4.2.5.3 | 249 | Cronograma Gantt_13 | 2024-08-30 | 2025-08-27 | 2024-08-30 | 2024-10-17 | 2025-10-14 | 2024-10-17 | 111 | 111 |
| 000112 |  | Transporte de Material Excedente D>1km | 83d | 2024-08-30 | 2024-11-20 | 000111 SS | 242d | 0d | 4.2.5.4 | 250 | Cronograma Gantt_13 | 2024-08-30 | 2025-08-27 | 2024-08-30 | 2024-11-20 | 2025-11-17 | 2024-11-20 | 112 | 112 |
| 000117 |  | Transporte de Material de Prestamo Cantera de Rio (Cuerpo de Terraplen) D<=1km | 30d | 2024-09-09 | 2024-10-08 | 000089 SS+11d | 265d | 0d | 4.2.5.9 | 255 | Cronograma Gantt_13 | 2024-09-09 | 2025-09-29 | 2024-09-09 | 2024-10-08 | 2025-10-28 | 2024-10-08 | 117 | 117 |
| 000115 |  | Transporte de Roca D<=1km | 30d | 2024-09-21 | 2024-10-20 | 000099 | 17d | 0d | 4.2.5.7 | 253 | Cronograma Gantt_13 | 2024-09-21 | 2024-10-08 | 2024-09-21 | 2024-10-20 | 2024-11-06 | 2024-10-20 | 115 | 115 |
| 000116 |  | Transporte de Roca D>1km | 45d | 2024-09-22 | 2024-11-05 | 000115 SS+1d | 17d |  | 4.2.5.8 | 254 | Cronograma Gantt_13 | 2024-09-22 | 2024-10-09 | 2024-09-22 | 2024-11-05 | 2024-11-22 | 2024-11-05 | 116 | 116 |
| 000118 |  | Transporte de Material de Prestamo Cantera de Rio (Cuerpo de Terraplen) D>1km | 20d | 2024-10-09 | 2024-10-28 | 000117 | 265d |  | 4.2.5.10 | 256 | Cronograma Gantt_13 | 2024-10-09 | 2025-10-29 | 2024-10-09 | 2024-10-28 | 2025-11-17 | 2024-10-28 | 118 | 118 |
| 000119 |  | Transporte de Material Seleccionado para Zanja D<=1km | 1d | 2024-10-10 | 2024-10-10 | 000091 | 14d | 0d | 4.2.5.11 | 257 | Cronograma Gantt_13 | 2024-10-10 | 2024-10-24 | 2024-10-10 | 2024-10-10 | 2024-10-24 | 2024-10-10 | 119 | 119 |
| 000120 |  | Transporte de Material Seleccionado para Zanja D>1km | 1d | 2024-10-10 | 2024-10-10 | 000119 SS | 14d |  | 4.2.5.12 | 258 | Cronograma Gantt_13 | 2024-10-10 | 2024-10-24 | 2024-10-10 | 2024-10-10 | 2024-10-24 | 2024-10-10 | 120 | 120 |
| 000113 |  | Transporte de Material de Prestamo (Afirmado) D<=1km | 8d | 2024-11-09 | 2024-11-16 | 000104 | 0d |  | 4.2.5.5 | 251 | Cronograma Gantt_13 | 2024-11-09 | 2024-11-09 | 2024-11-09 | 2024-11-16 | 2024-11-16 | 2024-11-16 | 113 | 113 |
| 000114 |  | Transporte de Material de Prestamo (Afirmado) D>1km | 12d | 2024-11-09 | 2024-11-20 | 000113 SS | 0d |  | 4.2.5.6 | 252 | Cronograma Gantt_13 | 2024-11-09 | 2024-11-09 | 2024-11-09 | 2024-11-20 | 2024-11-20 | 2024-11-20 | 114 | 114 |
|  | 000121 | **Obras Civiles (Interferencias)** |  | 2024-09-10 | 2024-10-27 |  |  |  |  |  |  |  |  |  |  |  |  |  |  |
| 000122 |  | Trazo y replanteo de interferencia | 1d | 2024-09-10 | 2024-09-10 | 000089 | 266d | 0d | 4.2.6.1 | 260 | Cronograma Gantt_13 | 2024-09-10 | 2025-10-01 | 2024-09-10 | 2024-09-10 | 2025-10-01 | 2024-09-10 | 122 | 122 |
| 000123 |  | Desvío provisional con tubería | 2d | 2024-09-11 | 2024-09-12 | 000122 | 311d | 110d | 4.2.6.2 | 261 | Cronograma Gantt_13 | 2024-09-11 | 2025-11-16 | 2024-09-11 | 2024-09-12 | 2025-11-17 | 2024-09-12 | 123 | 123 |
| 000124 |  | Desvío provisional en tierras | 5d | 2024-09-11 | 2024-09-15 | 000122 | 266d | 0d | 4.2.6.3 | 262 | Cronograma Gantt_13 | 2024-09-11 | 2025-10-02 | 2024-09-11 | 2024-09-15 | 2025-10-06 | 2024-09-15 | 124 | 124 |
| 000125 |  | Limpieza de terreno manual | 11d | 2024-09-16 | 2024-09-26 | 000124 | 266d | 0d | 4.2.6.4 | 263 | Cronograma Gantt_13 | 2024-09-16 | 2025-10-07 | 2024-09-16 | 2024-09-26 | 2025-10-17 | 2024-09-26 | 125 | 125 |
| 000126 |  | Excavaciones no clasificada para estructuras | 3d | 2024-09-27 | 2024-09-29 | 000125 | 283d | 0d | 4.2.6.5 | 264 | Cronograma Gantt_13 | 2024-09-27 | 2025-11-04 | 2024-09-27 | 2024-09-29 | 2025-11-06 | 2024-09-29 | 126 | 126 |
| 000127 |  | Excavacion no clasificada de zanja | 2d | 2024-09-27 | 2024-09-28 | 000125 | 266d | 0d | 4.2.6.6 | 265 | Cronograma Gantt_13 | 2024-09-27 | 2025-10-18 | 2024-09-27 | 2024-09-28 | 2025-10-19 | 2024-09-28 | 127 | 127 |
| 000128 |  | Relleno estructural | 6d | 2024-09-29 | 2024-10-04 | 000127 | 278d | 0d | 4.2.6.7 | 266 | Cronograma Gantt_13 | 2024-09-29 | 2025-11-01 | 2024-09-29 | 2024-10-04 | 2025-11-06 | 2024-10-04 | 128 | 128 |
| 000131 |  | Concreto de Nivelacion (f'c=100 kg/cm2) | 1d | 2024-09-29 | 2024-09-29 | 000127 | 266d | 0d | 4.2.6.10 | 269 | Cronograma Gantt_13 | 2024-09-29 | 2025-10-20 | 2024-09-29 | 2024-09-29 | 2025-10-20 | 2024-09-29 | 131 | 131 |
| 000132 |  | Concreto Clase C (f'c=280 kg/cm2) Premezclado - Cimientos reforzados | 1d | 2024-09-30 | 2024-09-30 | 000131 | 266d | 0d | 4.2.6.11 | 271 | Cronograma Gantt_13 | 2024-09-30 | 2025-10-21 | 2024-09-30 | 2024-09-30 | 2025-10-21 | 2024-09-30 | 132 | 132 |
| 000136 |  | Acero de refuerzo f'y=4200kg/cm2 | 11d | 2024-09-30 | 2024-10-10 | 000126 | 283d | 82d | 4.2.6.15 | 275 | Cronograma Gantt_13 | 2024-09-30 | 2025-11-07 | 2024-09-30 | 2024-10-10 | 2025-11-17 | 2024-10-10 | 136 | 136 |
| 000129 |  | Suministro de roca (Alcantarillas) | 1d | 2024-10-05 | 2024-10-05 | 000128 | 278d | 0d | 4.2.6.8 | 267 | Cronograma Gantt_13 | 2024-10-05 | 2025-11-07 | 2024-10-05 | 2024-10-05 | 2025-11-07 | 2024-10-05 | 129 | 129 |
| 000134 |  | Encofrado y Desencofrado Caravista | 4d | 2024-10-05 | 2024-10-08 | 000132 FS+4d | 266d | 0d | 4.2.6.13 | 273 | Cronograma Gantt_13 | 2024-10-05 | 2025-10-26 | 2024-10-05 | 2024-10-08 | 2025-10-29 | 2024-10-08 | 134 | 134 |
| 000130 |  | Colocación de roca en uña (Alcantarillas) | 1d | 2024-10-06 | 2024-10-06 | 000129 | 287d | 86d | 4.2.6.9 | 268 | Cronograma Gantt_13 | 2024-10-06 | 2025-11-17 | 2024-10-06 | 2024-10-06 | 2025-11-17 | 2024-10-06 | 130 | 130 |
| 000135 |  | Encofrado y Desencofrado Cara Oculta | 10d | 2024-10-06 | 2024-10-15 | 000132 FS+5d | 277d | 0d | 4.2.6.14 | 274 | Cronograma Gantt_13 | 2024-10-06 | 2025-11-07 | 2024-10-06 | 2024-10-15 | 2025-11-16 | 2024-10-15 | 135 | 135 |
| 000137 |  | Emboquillado de piedra e=0.20m | 6d | 2024-10-06 | 2024-10-11 | 000129 | 278d | 0d | 4.2.6.16 | 276 | Cronograma Gantt_13 | 2024-10-06 | 2025-11-08 | 2024-10-06 | 2024-10-11 | 2025-11-13 | 2024-10-11 | 137 | 137 |
| 000133 |  | Concreto Clase C (f'c=280 kg/cm2) Premezclado - Muros de contencion | 2d | 2024-10-09 | 2024-10-10 | 000134 | 266d | 0d | 4.2.6.12 | 272 | Cronograma Gantt_13 | 2024-10-09 | 2025-10-30 | 2024-10-09 | 2024-10-10 | 2025-10-31 | 2024-10-10 | 133 | 133 |
| 000143 |  | Pintura bituminosa | 4d | 2024-10-11 | 2024-10-14 | 000133 | 279d | 78d | 4.2.6.22 | 285 | Cronograma Gantt_13 | 2024-10-11 | 2025-11-14 | 2024-10-11 | 2024-10-14 | 2025-11-17 | 2024-10-14 | 143 | 143 |
| 000144 |  | Suministro e Instalación de geotextil | 1d | 2024-10-11 | 2024-10-11 | 000133 | 282d | 81d | 4.2.6.23 | 286 | Cronograma Gantt_13 | 2024-10-11 | 2025-11-17 | 2024-10-11 | 2024-10-11 | 2025-11-17 | 2024-10-11 | 144 | 144 |
| 000138 |  | Cama de arena e=0.20m | 1d | 2024-10-12 | 2024-10-12 | 000137 | 278d | 0d | 4.2.6.17 | 279 | Cronograma Gantt_13 | 2024-10-12 | 2025-11-14 | 2024-10-12 | 2024-10-12 | 2025-11-14 | 2024-10-12 | 138 | 138 |
| 000139 |  | Tubería HDPE Corrugada Ø=900mm (Suministro e instalación) | 3d | 2024-10-13 | 2024-10-15 | 000138 | 278d | 77d | 4.2.6.18 | 280 | Cronograma Gantt_13 | 2024-10-13 | 2025-11-15 | 2024-10-13 | 2024-10-15 | 2025-11-17 | 2024-10-15 | 139 | 139 |
| 000140 |  | Compuerta metálica tipo tarjeta 1.00x1.00m (Suministro e instalacion) | 5d | 2024-10-13 | 2024-10-17 | 000133 FS+2d | 276d | 75d | 4.2.6.19 | 282 | Cronograma Gantt_13 | 2024-10-13 | 2025-11-13 | 2024-10-13 | 2024-10-17 | 2025-11-17 | 2024-10-17 | 140 | 140 |
| 000141 |  | Sello en juntas | 2d | 2024-10-16 | 2024-10-17 | 000133 FS+5d | 266d | 0d | 4.2.6.20 | 283 | Cronograma Gantt_13 | 2024-10-16 | 2025-11-06 | 2024-10-16 | 2024-10-17 | 2025-11-07 | 2024-10-17 | 141 | 141 |
| 000142 |  | Waterstop (anillos de estanqueidad) | 1d | 2024-10-16 | 2024-10-16 | 000135 | 277d | 76d | 4.2.6.21 | 284 | Cronograma Gantt_13 | 2024-10-16 | 2025-11-17 | 2024-10-16 | 2024-10-16 | 2025-11-17 | 2024-10-16 | 142 | 142 |
| 000145 |  | Baranda metálica (suministro e instalación) | 5d | 2024-10-18 | 2024-10-22 | 000141 | 266d | 0d | 4.2.6.24 | 287 | Cronograma Gantt_13 | 2024-10-18 | 2025-11-08 | 2024-10-18 | 2024-10-22 | 2025-11-12 | 2024-10-22 | 145 | 145 |
| 000146 |  | Rejilla metálica de 2.8mx1.50m (Suministro e instalación) | 5d | 2024-10-23 | 2024-10-27 | 000145 | 266d | 65d | 4.2.6.25 | 288 | Cronograma Gantt_13 | 2024-10-23 | 2025-11-13 | 2024-10-23 | 2024-10-27 | 2025-11-17 | 2024-10-27 | 146 | 146 |

| ID | WBS | Activity | Duration | Start | Finish | Predecessors | Total float | Free float | MSP Outline Number | MSP Unique ID | MSP Project Name | Imported Early Start | Imported Late Start | Imported Start | Imported Early Finish | Imported Late Finish | Imported Finish | MSP ID | MSP Task Order |
| --- | --- | --- | --- | --- | --- | --- | --- | --- | --- | --- | --- | --- | --- | --- | --- | --- | --- | --- | --- |
|  | 000147 | **Mitigación Ambiental** |  | 2024-08-27 | 2024-08-28 |  |  |  |  |  |  |  |  |  |  |  |  |  |  |
| 000148 |  | Rescate camaron | 2d | 2024-08-27 | 2024-08-28 | 000007 | 0d |  | 4.2.7.1 | 1325 | Cronograma Gantt_13 | 2024-08-27 | 2024-08-27 | 2024-08-27 | 2024-08-28 | 2024-08-28 | 2024-08-28 | 148 | 148 |
|  | 000149 | **DI-PR-42-0-I** |  | 2024-07-26 | 2024-10-04 |  |  |  |  |  |  |  |  |  |  |  |  |  |  |
|  | 000150 | **Excavaciones** |  | 2024-07-28 | 2024-08-01 |  |  |  |  |  |  |  |  |  |  |  |  |  |  |
| 000151 |  | Desbroce | 1d | 2024-07-28 | 2024-07-28 | 000173 | 289d | 0d | 4.3.1.1 | 309 | Cronograma Gantt_13 | 2024-09-02 | 2025-09-10 | 2024-09-02 | 2024-09-02 | 2025-09-10 | 2024-09-02 | 151 | 151 |
| 000152 |  | Excavacion de Cimentacion | 1d | 2024-07-29 | 2024-07-29 | 000151 | 289d | 0d | 4.3.1.2 | 311 | Cronograma Gantt_13 | 2024-09-03 | 2025-09-11 | 2024-09-03 | 2024-09-03 | 2025-09-11 | 2024-09-03 | 152 | 152 |
| 000154 |  | Conformacion de Material Excedente en DMO | 1d | 2024-07-31 | 2024-07-31 | 000160 | 354d | 65d | 4.3.1.4 | 315 | Cronograma Gantt_13 | 2024-09-05 | 2025-11-17 | 2024-09-05 | 2024-09-05 | 2025-11-17 | 2024-09-05 | 154 | 154 |
| 000153 |  | Conformacion de Material Excedente en DME | 1d | 2024-08-01 | 2024-08-01 | 000162 | 353d | 64d | 4.3.1.3 | 314 | Cronograma Gantt_13 | 2024-09-06 | 2025-11-17 | 2024-09-06 | 2024-09-06 | 2025-11-17 | 2024-09-06 | 153 | 153 |
|  | 000155 | **Colocacion de Roca** |  | 2024-08-03 | 2024-09-06 |  |  |  |  |  |  |  |  |  |  |  |  |  |  |
| 000156 |  | Proteccion de Talud con Colchon Reno 6m Largo x e=0.30cm | 1d | 2024-08-03 | 2024-08-03 | 000152 FS+4d | 317d | 0d | 4.3.2.1 | 334 | Cronograma Gantt_13 | 2024-09-08 | 2025-10-14 | 2024-09-08 | 2024-09-08 | 2025-10-14 | 2024-09-08 | 156 | 156 |
| 000157 |  | Malla Gavion de 1m x 1m x 5m | 34d | 2024-08-04 | 2024-09-06 | 000156 | 317d | 28d | 4.3.2.2 | 335 | Cronograma Gantt_13 | 2024-09-09 | 2025-10-15 | 2024-09-09 | 2024-10-12 | 2025-11-17 | 2024-10-12 | 157 | 157 |
|  | 000158 | **Transportes** |  | 2024-07-29 | 2024-07-31 |  |  |  |  |  |  |  |  |  |  |  |  |  |  |
| 000159 |  | Transporte de Material Organico (a DMO) D<=1km | 1d | 2024-07-29 | 2024-07-29 | 000151 | 354d | 0d | 4.3.3.1 | 342 | Cronograma Gantt_13 | 2024-09-03 | 2025-11-15 | 2024-09-03 | 2024-09-03 | 2025-11-15 | 2024-09-03 | 159 | 159 |
| 000160 |  | Transporte de Material Organico (a DMO) D>1km | 2d | 2024-07-29 | 2024-07-30 | 000159 SS | 354d | 0d | 4.3.3.2 | 343 | Cronograma Gantt_13 | 2024-09-03 | 2025-11-15 | 2024-09-03 | 2024-09-04 | 2025-11-16 | 2024-09-04 | 160 | 160 |
| 000161 |  | Transporte de Material Excedente D<=1km | 1d | 2024-07-30 | 2024-07-30 | 000152 | 353d | 0d | 4.3.3.3 | 344 | Cronograma Gantt_13 | 2024-09-04 | 2025-11-15 | 2024-09-04 | 2024-09-04 | 2025-11-15 | 2024-09-04 | 161 | 161 |
| 000162 |  | Transporte de Material Excedente D>1km | 2d | 2024-07-30 | 2024-07-31 | 000161 SS | 353d | 0d | 4.3.3.4 | 345 | Cronograma Gantt_13 | 2024-09-04 | 2025-11-15 | 2024-09-04 | 2024-09-05 | 2025-11-16 | 2024-09-05 | 162 | 162 |
|  | 000163 | **Obras Civiles** |  | 2024-07-30 | 2024-10-04 |  |  |  |  |  |  |  |  |  |  |  |  |  |  |
| 000164 |  | Concreto de Nivelacion (f'c=100 kg/cm2) | 1d | 2024-07-30 | 2024-07-30 | 000152 | 289d | 0d | 4.3.4.1 | 389 | Cronograma Gantt_13 | 2024-09-04 | 2025-09-12 | 2024-09-04 | 2024-09-04 | 2025-09-12 | 2024-09-04 | 164 | 164 |
| 000169 |  | Acero de refuerzo f'y=4200kg/cm2 | 17d | 2024-07-31 | 2024-08-16 | 000164 | 289d | 0d | 4.3.4.6 | 394 | Cronograma Gantt_13 | 2024-09-05 | 2025-09-13 | 2024-09-05 | 2024-09-21 | 2025-09-29 | 2024-09-21 | 169 | 169 |
| 000165 |  | Concreto Clase C (f'c=280 kg/cm2) Premezclado - Cimientos reforzados | 6d | 2024-08-02 | 2024-08-07 | 000169 SS+2d | 289d | 0d | 4.3.4.2 | 390 | Cronograma Gantt_13 | 2024-09-07 | 2025-09-15 | 2024-09-07 | 2024-09-12 | 2025-09-20 | 2024-09-12 | 165 | 165 |
| 000167 |  | Encofrado y Desencofrado Caravista | 23d | 2024-08-12 | 2024-09-03 | 000165 FS+4d | 289d | 0d | 4.3.4.4 | 392 | Cronograma Gantt_13 | 2024-09-17 | 2025-09-25 | 2024-09-17 | 2024-10-09 | 2025-10-17 | 2024-10-09 | 167 | 167 |
| 000168 |  | Encofrado y Desencofrado Cara Oculta | 6d | 2024-08-13 | 2024-08-18 | 000165 FS+5d | 305d | 16d | 4.3.4.5 | 393 | Cronograma Gantt_13 | 2024-09-18 | 2025-10-12 | 2024-09-18 | 2024-09-23 | 2025-10-17 | 2024-09-23 | 168 | 168 |
| 000166 |  | Concreto Clase C (f'c=280 kg/cm2) Premezclado - Muros de contencion | 7d | 2024-09-04 | 2024-09-10 | 000168, 000167 | 289d | 0d | 4.3.4.3 | 391 | Cronograma Gantt_13 | 2024-10-10 | 2025-10-18 | 2024-10-10 | 2024-10-16 | 2025-10-24 | 2024-10-16 | 166 | 166 |
| 000170 |  | Junta de dilatación | 2d | 2024-09-17 | 2024-09-18 | 000166 FS+6d | 289d | 0d | 4.3.4.7 | 395 | Cronograma Gantt_13 | 2024-10-23 | 2025-10-31 | 2024-10-23 | 2024-10-24 | 2025-11-01 | 2024-10-24 | 170 | 170 |
| 000171 |  | Pintura bituminosa | 16d | 2024-09-19 | 2024-10-04 | 000170 | 289d | 0d | 4.3.4.8 | 396 | Cronograma Gantt_13 | 2024-10-25 | 2025-11-02 | 2024-10-25 | 2024-11-09 | 2025-11-17 | 2024-11-09 | 171 | 171 |

| ID | WBS | Activity | Duration | Start | Finish | Predecessors | Total float | Free float | MSP Outline Number | MSP Unique ID | MSP Project Name | Imported Early Start | Imported Late Start | Imported Start | Imported Early Finish | Imported Late Finish | Imported Finish | MSP ID | MSP Task Order |
| --- | --- | --- | --- | --- | --- | --- | --- | --- | --- | --- | --- | --- | --- | --- | --- | --- | --- | --- | --- |
|  | 000172 | **Mitigación Ambiental** |  | 2024-07-26 | 2024-07-27 |  |  |  |  |  |  |  |  |  |  |  |  |  |  |
| 000173 |  | Rescate camaron | 2d | 2024-07-26 | 2024-07-27 | 000009 | 289d | 0d | 4.3.5.1 | 1327 | Cronograma Gantt_13 | 2024-08-31 | 2025-09-08 | 2024-08-31 | 2024-09-01 | 2025-09-09 | 2024-09-01 | 173 | 173 |
|  | 000174 | **DI-PR-42-5-I** |  | 2024-07-29 | 2024-09-09 |  |  |  |  |  |  |  |  |  |  |  |  |  |  |
|  | 000175 | **Excavaciones** |  | 2024-07-31 | 2024-08-16 |  |  |  |  |  |  |  |  |  |  |  |  |  |  |
| 000176 |  | Desbroce | 1d | 2024-07-31 | 2024-07-31 | 000211 | 314d | 0d | 4.4.1.1 | 404 | Cronograma Gantt_13 | 2024-09-05 | 2025-10-08 | 2024-09-05 | 2024-09-05 | 2025-10-08 | 2024-09-05 | 176 | 176 |
| 000177 |  | Excavacion de Cimentacion | 3d | 2024-08-01 | 2024-08-03 | 000176 | 314d | 0d | 4.4.1.2 | 406 | Cronograma Gantt_13 | 2024-09-06 | 2025-10-09 | 2024-09-06 | 2024-09-08 | 2025-10-11 | 2024-09-08 | 177 | 177 |
| 000179 |  | Conformacion de Material Excedente en DMO | 1d | 2024-08-08 | 2024-08-08 | 000186 | 346d | 32d | 4.4.1.4 | 410 | Cronograma Gantt_13 | 2024-09-13 | 2025-11-17 | 2024-09-13 | 2024-09-13 | 2025-11-17 | 2024-09-13 | 179 | 179 |
| 000178 |  | Conformacion de Material Excedente en DME | 1d | 2024-08-16 | 2024-08-16 | 000188 | 338d | 24d | 4.4.1.3 | 409 | Cronograma Gantt_13 | 2024-09-21 | 2025-11-17 | 2024-09-21 | 2024-09-21 | 2025-11-17 | 2024-09-21 | 178 | 178 |
|  | 000180 | **Rellenos** |  | 2024-08-22 | 2024-09-06 |  |  |  |  |  |  |  |  |  |  |  |  |  |  |
| 000181 |  | Relleno estructural | 16d | 2024-08-22 | 2024-09-06 | 000194 | 314d | 0d | 4.4.2.1 | 420 | Cronograma Gantt_13 | 2024-09-27 | 2025-10-30 | 2024-09-27 | 2024-10-12 | 2025-11-14 | 2024-10-12 | 181 | 181 |
|  | 000182 | **Colocacion de Roca** |  | 2024-09-07 | 2024-09-09 |  |  |  |  |  |  |  |  |  |  |  |  |  |  |
| 000183 |  | Colocacion de Roca en Talud | 3d | 2024-09-07 | 2024-09-09 | 000190, 000181 | 314d | 0d | 4.4.3.1 | 427 | Cronograma Gantt_13 | 2024-10-13 | 2025-11-15 | 2024-10-13 | 2024-10-15 | 2025-11-17 | 2024-10-15 | 183 | 183 |
|  | 000184 | **Transportes** |  | 2024-08-01 | 2024-08-23 |  |  |  |  |  |  |  |  |  |  |  |  |  |  |
| 000185 |  | Transporte de Material Organico (a DMO) D<=1km | 2d | 2024-08-01 | 2024-08-02 | 000176 | 346d | 0d | 4.4.4.1 | 437 | Cronograma Gantt_13 | 2024-09-06 | 2025-11-10 | 2024-09-06 | 2024-09-07 | 2025-11-11 | 2024-09-07 | 185 | 185 |
| 000186 |  | Transporte de Material Organico (a DMO) D>1km | 7d | 2024-08-01 | 2024-08-07 | 000185 SS | 346d | 0d | 4.4.4.2 | 438 | Cronograma Gantt_13 | 2024-09-06 | 2025-11-10 | 2024-09-06 | 2024-09-12 | 2025-11-16 | 2024-09-12 | 186 | 186 |
| 000187 |  | Transporte de Material Excedente D<=1km | 4d | 2024-08-04 | 2024-08-07 | 000177 | 314d | 0d | 4.4.4.3 | 439 | Cronograma Gantt_13 | 2024-09-09 | 2025-10-12 | 2024-09-09 | 2024-09-12 | 2025-10-15 | 2024-09-12 | 187 | 187 |
| 000188 |  | Transporte de Material Excedente D>1km | 12d | 2024-08-04 | 2024-08-15 | 000187 SS | 314d | 0d | 4.4.4.4 | 440 | Cronograma Gantt_13 | 2024-09-09 | 2025-10-12 | 2024-09-09 | 2024-09-20 | 2025-10-23 | 2024-09-20 | 188 | 188 |
| 000189 |  | Transporte de Material de Prestamo (Afirmado) D<=1km | 2d | 2024-08-16 | 2024-08-17 | 000188 | 314d | 0d | 4.4.4.5 | 441 | Cronograma Gantt_13 | 2024-09-21 | 2025-10-24 | 2024-09-21 | 2024-09-22 | 2025-10-25 | 2024-09-22 | 189 | 189 |
| 000190 |  | Transporte de Material de Prestamo (Afirmado) D>1km | 1d | 2024-08-16 | 2024-08-16 | 000189 SS | 314d | 0d | 4.4.4.6 | 442 | Cronograma Gantt_13 | 2024-09-21 | 2025-10-24 | 2024-09-21 | 2024-09-21 | 2025-10-24 | 2024-09-21 | 190 | 190 |
| 000193 |  | Transporte de Material de Prestamo Cantera de Rio (Cuerpo de Terraplen) D<=1km | 3d | 2024-08-17 | 2024-08-19 | 000190 | 314d | 0d | 4.4.4.9 | 445 | Cronograma Gantt_13 | 2024-09-22 | 2025-10-25 | 2024-09-22 | 2024-09-24 | 2025-10-27 | 2024-09-24 | 193 | 193 |
| 000194 |  | Transporte de Material de Prestamo Cantera de Rio (Cuerpo de Terraplen) D>1km | 5d | 2024-08-17 | 2024-08-21 | 000193 SS | 314d | 0d | 4.4.4.10 | 446 | Cronograma Gantt_13 | 2024-09-22 | 2025-10-25 | 2024-09-22 | 2024-09-26 | 2025-10-29 | 2024-09-26 | 194 | 194 |
| 000191 |  | Transporte de Roca D<=1km | 2d | 2024-08-22 | 2024-08-23 | 000194 | 331d | 0d | 4.4.4.7 | 443 | Cronograma Gantt_13 | 2024-09-27 | 2025-11-16 | 2024-09-27 | 2024-09-28 | 2025-11-17 | 2024-09-28 | 191 | 191 |
| 000192 |  | Transporte de Roca D>1km | 1d | 2024-08-22 | 2024-08-22 | 000191 SS | 332d |  | 4.4.4.8 | 444 | Cronograma Gantt_13 | 2024-09-27 | 2025-11-17 | 2024-09-27 | 2024-09-27 | 2025-11-17 | 2024-09-27 | 192 | 192 |
|  | 000195 | **Obras Civiles (Interferencias)** |  | 2024-08-04 | 2024-08-25 |  |  |  |  |  |  |  |  |  |  |  |  |  |  |
| 000196 |  | Trazo y replanteo de interferencia | 1d | 2024-08-04 | 2024-08-04 | 000177 | 329d | 0d | 4.4.5.1 | 450 | Cronograma Gantt_13 | 2024-09-09 | 2025-10-27 | 2024-09-09 | 2024-09-09 | 2025-10-27 | 2024-09-09 | 196 | 196 |
| 000197 |  | Desvío provisional con tubería | 1d | 2024-08-05 | 2024-08-05 | 000196 | 329d | 0d | 4.4.5.2 | 451 | Cronograma Gantt_13 | 2024-09-10 | 2025-10-28 | 2024-09-10 | 2024-09-10 | 2025-10-28 | 2024-09-10 | 197 | 197 |
| 000198 |  | Limpieza de terreno manual | 1d | 2024-08-06 | 2024-08-06 | 000197 | 329d | 0d | 4.4.5.3 | 453 | Cronograma Gantt_13 | 2024-09-11 | 2025-10-29 | 2024-09-11 | 2024-09-11 | 2025-10-29 | 2024-09-11 | 198 | 198 |
| 000199 |  | Excavaciones no clasificada para estructuras | 1d | 2024-08-07 | 2024-08-07 | 000198 | 329d | 0d | 4.4.5.4 | 454 | Cronograma Gantt_13 | 2024-09-12 | 2025-10-30 | 2024-09-12 | 2024-09-12 | 2025-10-30 | 2024-09-12 | 199 | 199 |
| 000200 |  | Concreto de Nivelacion (f'c=100 kg/cm2) | 1d | 2024-08-08 | 2024-08-08 | 000199 | 329d | 0d | 4.4.5.5 | 459 | Cronograma Gantt_13 | 2024-09-13 | 2025-10-31 | 2024-09-13 | 2024-09-13 | 2025-10-31 | 2024-09-13 | 200 | 200 |
| 000205 |  | Acero de refuerzo f'y=4200kg/cm2 | 3d | 2024-08-09 | 2024-08-11 | 000200 | 329d | 0d | 4.4.5.10 | 465 | Cronograma Gantt_13 | 2024-09-14 | 2025-11-01 | 2024-09-14 | 2024-09-16 | 2025-11-03 | 2024-09-16 | 205 | 205 |
| 000201 |  | Concreto Clase C (f'c=280 kg/cm2) Premezclado - Cimientos reforzados | 1d | 2024-08-12 | 2024-08-12 | 000205 | 329d | 0d | 4.4.5.6 | 461 | Cronograma Gantt_13 | 2024-09-17 | 2025-11-04 | 2024-09-17 | 2024-09-17 | 2025-11-04 | 2024-09-17 | 201 | 201 |
| 000204 |  | Encofrado y Desencofrado Cara Oculta | 2d | 2024-08-13 | 2024-08-14 | 000201 | 329d | 0d | 4.4.5.9 | 464 | Cronograma Gantt_13 | 2024-09-18 | 2025-11-05 | 2024-09-18 | 2024-09-19 | 2025-11-06 | 2024-09-19 | 204 | 204 |
| 000203 |  | Encofrado y Desencofrado Caravista | 2d | 2024-08-15 | 2024-08-16 | 000204 | 329d | 0d | 4.4.5.8 | 463 | Cronograma Gantt_13 | 2024-09-20 | 2025-11-07 | 2024-09-20 | 2024-09-21 | 2025-11-08 | 2024-09-21 | 203 | 203 |
| 000202 |  | Concreto Clase C (f'c=280 kg/cm2) Premezclado - Muros de contencion | 1d | 2024-08-17 | 2024-08-17 | 000203 | 329d | 0d | 4.4.5.7 | 462 | Cronograma Gantt_13 | 2024-09-22 | 2025-11-09 | 2024-09-22 | 2024-09-22 | 2025-11-09 | 2024-09-22 | 202 | 202 |
| 000206 |  | Emboquillado de piedra e=0.30m | 2d | 2024-08-20 | 2024-08-21 | 000202 FS+2d | 333d | 19d | 4.4.5.11 | 467 | Cronograma Gantt_13 | 2024-09-25 | 2025-11-16 | 2024-09-25 | 2024-09-26 | 2025-11-17 | 2024-09-26 | 206 | 206 |
| 000207 |  | Sello en juntas | 1d | 2024-08-20 | 2024-08-20 | 000202 FS+2d | 329d | 0d | 4.4.5.12 | 473 | Cronograma Gantt_13 | 2024-09-25 | 2025-11-12 | 2024-09-25 | 2024-09-25 | 2025-11-12 | 2024-09-25 | 207 | 207 |
| 000209 |  | Compuerta metálica tipo tarjeta 1.40x1.40 m (Suministro e instalacion) | 5d | 2024-08-21 | 2024-08-25 | 000207 | 329d | 15d | 4.4.5.14 | 479 | Cronograma Gantt_13 | 2024-09-26 | 2025-11-13 | 2024-09-26 | 2024-09-30 | 2025-11-17 | 2024-09-30 | 209 | 209 |
| 000208 |  | Pintura bituminosa | 1d | 2024-08-22 | 2024-08-22 | 000202 FS+4d | 332d | 18d | 4.4.5.13 | 475 | Cronograma Gantt_13 | 2024-09-27 | 2025-11-17 | 2024-09-27 | 2024-09-27 | 2025-11-17 | 2024-09-27 | 208 | 208 |

| ID | WBS | Activity | Duration | Start | Finish | Predecessors | Total float | Free float | MSP Outline Number | MSP Unique ID | MSP Project Name | Imported Early Start | Imported Late Start | Imported Start | Imported Early Finish | Imported Late Finish | Imported Finish | MSP ID | MSP Task Order |
| --- | --- | --- | --- | --- | --- | --- | --- | --- | --- | --- | --- | --- | --- | --- | --- | --- | --- | --- | --- |
|  | 000210 | **Mitigación Ambiental** |  | 2024-07-29 | 2024-07-30 |  |  |  |  |  |  |  |  |  |  |  |  |  |  |
| 000211 |  | Rescate camaron | 2d | 2024-07-29 | 2024-07-30 | 000011 | 314d | 0d | 4.4.6.1 | 1329 | Cronograma Gantt_13 | 2024-09-03 | 2025-10-06 | 2024-09-03 | 2024-09-04 | 2025-10-07 | 2024-09-04 | 211 | 211 |
|  | 000212 | **SEGUNDA ETAPA** |  | 2025-05-01 | 2025-11-17 |  |  |  |  |  |  |  |  |  |  |  |  |  |  |
|  | 000213 | **DI-PR-53-I** |  | 2025-05-01 | 2025-08-09 |  |  |  |  |  |  |  |  |  |  |  |  |  |  |
|  | 000214 | **Excavaciones** |  | 2025-05-03 | 2025-05-31 |  |  |  |  |  |  |  |  |  |  |  |  |  |  |
| 000215 |  | Desbroce | 2d | 2025-05-03 | 2025-05-04 | 000274 | 0d |  | 5.1.1.1 | 502 | Cronograma Gantt_13 | 2025-05-03 | 2025-05-03 | 2025-05-03 | 2025-05-04 | 2025-05-04 | 2025-05-04 | 215 | 215 |
| 000216 |  | Remocion de Dique Existente | 1d | 2025-05-05 | 2025-05-05 | 000215 | 0d |  | 5.1.1.2 | 503 | Cronograma Gantt_13 | 2025-05-05 | 2025-05-05 | 2025-05-05 | 2025-05-05 | 2025-05-05 | 2025-05-05 | 216 | 216 |
| 000217 |  | Excavacion de Cimentacion | 20d | 2025-05-06 | 2025-05-25 | 000216 | 0d |  | 5.1.1.3 | 504 | Cronograma Gantt_13 | 2025-05-06 | 2025-05-06 | 2025-05-06 | 2025-05-25 | 2025-05-25 | 2025-05-25 | 217 | 217 |
| 000218 |  | Perfilado y Conformacion de Plataforma de Fundacion | 4d | 2025-05-08 | 2025-05-11 | 000217 SS+2d | 190d | 90d | 5.1.1.4 | 505 | Cronograma Gantt_13 | 2025-05-08 | 2025-11-14 | 2025-05-08 | 2025-05-11 | 2025-11-17 | 2025-05-11 | 218 | 218 |
| 000219 |  | Excavacion de Uña | 12d | 2025-05-08 | 2025-05-19 | 000217 SS+2d | 182d | 82d | 5.1.1.5 | 506 | Cronograma Gantt_13 | 2025-05-08 | 2025-11-06 | 2025-05-08 | 2025-05-19 | 2025-11-17 | 2025-05-19 | 219 | 219 |
| 000222 |  | Excavacion Localizada - Sobreexcavacion | 11d | 2025-05-11 | 2025-05-21 | 000216 FS+5d | 180d | 80d | 5.1.1.8 | 509 | Cronograma Gantt_13 | 2025-05-11 | 2025-11-07 | 2025-05-11 | 2025-05-21 | 2025-11-17 | 2025-05-21 | 222 | 222 |
| 000220 |  | Conformacion de Material Excedente en DME | 19d | 2025-05-13 | 2025-05-31 | 000240 FS-18d | 170d | 70d | 5.1.1.6 | 507 | Cronograma Gantt_13 | 2025-05-13 | 2025-10-30 | 2025-05-13 | 2025-05-31 | 2025-11-17 | 2025-05-31 | 220 | 220 |
| 000221 |  | Conformacion de Material Excedente en DMO | 3d | 2025-05-16 | 2025-05-18 | 000238 | 183d | 83d | 5.1.1.7 | 508 | Cronograma Gantt_13 | 2025-05-16 | 2025-11-15 | 2025-05-16 | 2025-05-18 | 2025-11-17 | 2025-05-18 | 221 | 221 |
|  | 000223 | **Rellenos** |  | 2025-06-08 | 2025-07-31 |  |  |  |  |  |  |  |  |  |  |  |  |  |  |
| 000224 |  | Relleno con Material Granular (incluye extraccion de material, zarandeo y combinado) | 9d | 2025-06-08 | 2025-06-16 | 000246 FS-8d | 154d | 54d | 5.1.2.1 | 512 | Cronograma Gantt_13 | 2025-06-08 | 2025-11-09 | 2025-06-08 | 2025-06-16 | 2025-11-17 | 2025-06-16 | 224 | 224 |
| 000227 |  | Relleno con Material Seleccionado (incluye extraccion de material, zarandeo y combinado) | 11d | 2025-06-11 | 2025-06-21 | 000246 FS-5d | 128d | 0d | 5.1.2.4 | 516 | Cronograma Gantt_13 | 2025-06-11 | 2025-10-17 | 2025-06-11 | 2025-06-21 | 2025-10-27 | 2025-06-21 | 227 | 227 |
| 000226 |  | Perfilado de Talud Dique | 2d | 2025-06-22 | 2025-06-23 | 000227 | 128d | 0d | 5.1.2.3 | 515 | Cronograma Gantt_13 | 2025-06-22 | 2025-10-28 | 2025-06-22 | 2025-06-23 | 2025-10-29 | 2025-06-23 | 226 | 226 |
| 000225 |  | Relleno Afirmado | 1d | 2025-07-12 | 2025-07-12 | 000242, 000231 | 128d | 28d | 5.1.2.2 | 514 | Cronograma Gantt_13 | 2025-07-12 | 2025-11-17 | 2025-07-12 | 2025-07-12 | 2025-11-17 | 2025-07-12 | 225 | 225 |
| 000228 |  | Grava para Drenaje | 1d | 2025-07-31 | 2025-07-31 | 000233 | 109d | 9d | 5.1.2.5 | 517 | Cronograma Gantt_13 | 2025-07-31 | 2025-11-17 | 2025-07-31 | 2025-07-31 | 2025-11-17 | 2025-07-31 | 228 | 228 |
|  | 000229 | **Geotextil** |  | 2025-06-24 | 2025-07-11 |  |  |  |  |  |  |  |  |  |  |  |  |  |  |
| 000230 |  | Instalacion de Geotextil 400gr/m2 | 17d | 2025-06-24 | 2025-07-10 | 000226 | 128d | 0d | 5.1.3.1 | 520 | Cronograma Gantt_13 | 2025-06-24 | 2025-10-30 | 2025-06-24 | 2025-07-10 | 2025-11-15 | 2025-07-10 | 230 | 230 |
| 000231 |  | Zanja de Anclaje | 13d | 2025-06-29 | 2025-07-11 | 000248, 000230 SS+5d | 128d | 0d | 5.1.3.2 | 521 | Cronograma Gantt_13 | 2025-06-29 | 2025-11-04 | 2025-06-29 | 2025-07-11 | 2025-11-16 | 2025-07-11 | 231 | 231 |
|  | 000232 | **Colocacion de Roca** |  | 2025-05-06 | 2025-08-09 |  |  |  |  |  |  |  |  |  |  |  |  |  |  |
| 000235 |  | Extraccion de Rocas Reutilizables | 4d | 2025-05-06 | 2025-05-09 | 000216 | 192d | 92d | 5.1.4.3 | 526 | Cronograma Gantt_13 | 2025-05-06 | 2025-11-14 | 2025-05-06 | 2025-05-09 | 2025-11-17 | 2025-05-09 | 235 | 235 |
| 000233 |  | Colocacion de Roca en Uña | 21d | 2025-07-10 | 2025-07-30 | 000244 FS-10d | 100d | 0d | 5.1.4.1 | 524 | Cronograma Gantt_13 | 2025-07-10 | 2025-10-18 | 2025-07-10 | 2025-07-30 | 2025-11-07 | 2025-07-30 | 233 | 233 |
| 000234 |  | Colocacion de Roca en Talud | 21d | 2025-07-20 | 2025-08-09 | 000233 SS+10d | 100d | 0d | 5.1.4.2 | 525 | Cronograma Gantt_13 | 2025-07-20 | 2025-10-28 | 2025-07-20 | 2025-08-09 | 2025-11-17 | 2025-08-09 | 234 | 234 |

| ID | WBS | Activity | Duration | Start | Finish | Predecessors | Total float | Free float | MSP Outline Number | MSP Unique ID | MSP Project Name | Imported Early Start | Imported Late Start | Imported Start | Imported Early Finish | Imported Late Finish | Imported Finish | MSP ID | MSP Task Order |
| --- | --- | --- | --- | --- | --- | --- | --- | --- | --- | --- | --- | --- | --- | --- | --- | --- | --- | --- | --- |
|  | 000236 | **Transportes** |  | 2025-05-05 | 2025-07-19 |  |  |  |  |  |  |  |  |  |  |  |  |  |  |
| 000237 |  | Transporte de Material Organico (a DMO) D<=1km | 5d | 2025-05-05 | 2025-05-09 | 000215 | 183d | 0d | 5.1.5.1 | 535 | Cronograma Gantt_13 | 2025-05-05 | 2025-11-04 | 2025-05-05 | 2025-05-09 | 2025-11-08 | 2025-05-09 | 237 | 237 |
| 000238 |  | Transporte de Material Organico (a DMO) D>1km | 11d | 2025-05-05 | 2025-05-15 | 000237 SS | 183d | 0d | 5.1.5.2 | 536 | Cronograma Gantt_13 | 2025-05-05 | 2025-11-04 | 2025-05-05 | 2025-05-15 | 2025-11-14 | 2025-05-15 | 238 | 238 |
| 000239 |  | Transporte de Material Excedente D<=1km | 16d | 2025-05-11 | 2025-05-26 | 000217 SS+5d | 170d | 0d | 5.1.5.3 | 537 | Cronograma Gantt_13 | 2025-05-11 | 2025-10-28 | 2025-05-11 | 2025-05-26 | 2025-11-12 | 2025-05-26 | 239 | 239 |
| 000240 |  | Transporte de Material Excedente D>1km | 20d | 2025-05-11 | 2025-05-30 | 000239 SS | 170d | 0d | 5.1.5.4 | 538 | Cronograma Gantt_13 | 2025-05-11 | 2025-10-28 | 2025-05-11 | 2025-05-30 | 2025-11-16 | 2025-05-30 | 240 | 240 |
| 000245 |  | Transporte de Material de Prestamo Cantera de Rio (Cuerpo de Terraplen) D<=1km | 16d | 2025-05-16 | 2025-05-31 | 000217 SS+10d | 100d | 0d | 5.1.5.9 | 543 | Cronograma Gantt_13 | 2025-05-16 | 2025-08-24 | 2025-05-16 | 2025-05-31 | 2025-09-08 | 2025-05-31 | 245 | 245 |
| 000246 |  | Transporte de Material de Prestamo Cantera de Rio (Cuerpo de Terraplen) D>1km | 31d | 2025-05-16 | 2025-06-15 | 000245 SS | 100d | 0d | 5.1.5.10 | 544 | Cronograma Gantt_13 | 2025-05-16 | 2025-08-24 | 2025-05-16 | 2025-06-15 | 2025-09-23 | 2025-06-15 | 246 | 246 |
| 000247 |  | Transporte de Material Seleccionado para Zanja D<=1km | 1d | 2025-06-16 | 2025-06-16 | 000246 | 100d | 0d | 5.1.5.11 | 545 | Cronograma Gantt_13 | 2025-06-16 | 2025-09-24 | 2025-06-16 | 2025-06-16 | 2025-09-24 | 2025-06-16 | 247 | 247 |
| 000248 |  | Transporte de Material Seleccionado para Zanja D>1km | 1d | 2025-06-16 | 2025-06-16 | 000247 SS | 100d | 0d | 5.1.5.12 | 546 | Cronograma Gantt_13 | 2025-06-16 | 2025-09-24 | 2025-06-16 | 2025-06-16 | 2025-09-24 | 2025-06-16 | 248 | 248 |
| 000241 |  | Transporte de Material de Prestamo (Afirmado) D<=1km | 3d | 2025-06-17 | 2025-06-19 | 000248 | 100d | 0d | 5.1.5.5 | 539 | Cronograma Gantt_13 | 2025-06-17 | 2025-09-25 | 2025-06-17 | 2025-06-19 | 2025-09-27 | 2025-06-19 | 241 | 241 |
| 000242 |  | Transporte de Material de Prestamo (Afirmado) D>1km | 10d | 2025-06-17 | 2025-06-26 | 000241 SS | 100d | 0d | 5.1.5.6 | 540 | Cronograma Gantt_13 | 2025-06-17 | 2025-09-25 | 2025-06-17 | 2025-06-26 | 2025-10-04 | 2025-06-26 | 242 | 242 |
| 000243 |  | Transporte de Roca D<=1km | 15d | 2025-06-27 | 2025-07-11 | 000242 | 100d | 0d | 5.1.5.7 | 541 | Cronograma Gantt_13 | 2025-06-27 | 2025-10-05 | 2025-06-27 | 2025-07-11 | 2025-10-19 | 2025-07-11 | 243 | 243 |
| 000244 |  | Transporte de Roca D>1km | 23d | 2025-06-27 | 2025-07-19 | 000243 SS | 100d | 0d | 5.1.5.8 | 542 | Cronograma Gantt_13 | 2025-06-27 | 2025-10-05 | 2025-06-27 | 2025-07-19 | 2025-10-27 | 2025-07-19 | 244 | 244 |
|  | 000249 | **Obras Civiles (Interferencias)** |  | 2025-05-05 | 2025-06-17 |  |  |  |  |  |  |  |  |  |  |  |  |  |  |
| 000250 |  | Trazo y replanteo de interferencia | 1d | 2025-05-05 | 2025-05-05 | 000215 | 93d | 0d | 5.1.6.1 | 548 | Cronograma Gantt_13 | 2025-05-05 | 2025-08-06 | 2025-05-05 | 2025-05-05 | 2025-08-06 | 2025-05-05 | 250 | 250 |
| 000253 |  | Limpieza de terreno manual | 9d | 2025-05-06 | 2025-05-14 | 000250 | 93d | 0d | 5.1.6.4 | 551 | Cronograma Gantt_13 | 2025-05-06 | 2025-08-07 | 2025-05-06 | 2025-05-14 | 2025-08-15 | 2025-05-14 | 253 | 253 |
| 000254 |  | Excavaciones no clasificada para estructuras | 1d | 2025-05-15 | 2025-05-15 | 000253 | 93d | 0d | 5.1.6.5 | 552 | Cronograma Gantt_13 | 2025-05-15 | 2025-08-16 | 2025-05-15 | 2025-05-15 | 2025-08-16 | 2025-05-15 | 254 | 254 |
| 000255 |  | Excavacion no clasificada de zanja | 4d | 2025-05-15 | 2025-05-18 | 000253 | 110d | 0d | 5.1.6.6 | 553 | Cronograma Gantt_13 | 2025-05-15 | 2025-09-02 | 2025-05-15 | 2025-05-18 | 2025-09-05 | 2025-05-18 | 255 | 255 |
| 000256 |  | Relleno estructural | 3d | 2025-05-16 | 2025-05-18 | 000254 | 93d | 0d | 5.1.6.7 | 554 | Cronograma Gantt_13 | 2025-05-16 | 2025-08-17 | 2025-05-16 | 2025-05-18 | 2025-08-19 | 2025-05-18 | 256 | 256 |
| 000251 |  | Desvío provisional con tubería | 1d | 2025-05-19 | 2025-05-19 | 000255 | 182d | 82d | 5.1.6.2 | 549 | Cronograma Gantt_13 | 2025-05-19 | 2025-11-17 | 2025-05-19 | 2025-05-19 | 2025-11-17 | 2025-05-19 | 251 | 251 |
| 000252 |  | Desvío provisional en tierras | 5d | 2025-05-19 | 2025-05-23 | 000255 | 178d | 78d | 5.1.6.3 | 550 | Cronograma Gantt_13 | 2025-05-19 | 2025-11-13 | 2025-05-19 | 2025-05-23 | 2025-11-17 | 2025-05-23 | 252 | 252 |
| 000257 |  | Suministro de roca (Alcantarillas) | 1d | 2025-05-19 | 2025-05-19 | 000256 | 181d | 0d | 5.1.6.8 | 555 | Cronograma Gantt_13 | 2025-05-19 | 2025-11-16 | 2025-05-19 | 2025-05-19 | 2025-11-16 | 2025-05-19 | 257 | 257 |
| 000259 |  | Concreto de Nivelacion (f'c=100 kg/cm2) | 2d | 2025-05-19 | 2025-05-20 | 000256 | 93d | 0d | 5.1.6.10 | 557 | Cronograma Gantt_13 | 2025-05-19 | 2025-08-20 | 2025-05-19 | 2025-05-20 | 2025-08-21 | 2025-05-20 | 259 | 259 |
| 000258 |  | Colocación de roca en uña (Alcantarillas) | 1d | 2025-05-20 | 2025-05-20 | 000257 | 181d | 81d | 5.1.6.9 | 556 | Cronograma Gantt_13 | 2025-05-20 | 2025-11-17 | 2025-05-20 | 2025-05-20 | 2025-11-17 | 2025-05-20 | 258 | 258 |
| 000264 |  | Acero de refuerzo f'y=4200kg/cm2 | 6d | 2025-05-21 | 2025-05-26 | 000259 | 93d | 0d | 5.1.6.15 | 563 | Cronograma Gantt_13 | 2025-05-21 | 2025-08-22 | 2025-05-21 | 2025-05-26 | 2025-08-27 | 2025-05-26 | 264 | 264 |
| 000260 |  | Concreto Clase C (f'c=280 kg/cm2) Premezclado - Cimientos reforzados | 1d | 2025-05-27 | 2025-05-27 | 000264 | 93d | 0d | 5.1.6.11 | 559 | Cronograma Gantt_13 | 2025-05-27 | 2025-08-28 | 2025-05-27 | 2025-05-27 | 2025-08-28 | 2025-05-27 | 260 | 260 |
| 000262 |  | Encofrado y Desencofrado Caravista | 4d | 2025-05-28 | 2025-05-31 | 000260 | 170d | 70d | 5.1.6.13 | 561 | Cronograma Gantt_13 | 2025-05-28 | 2025-11-14 | 2025-05-28 | 2025-05-31 | 2025-11-17 | 2025-05-31 | 262 | 262 |
| 000263 |  | Encofrado y Desencofrado Cara Oculta | 6d | 2025-05-28 | 2025-06-02 | 000260 | 93d | 0d | 5.1.6.14 | 562 | Cronograma Gantt_13 | 2025-05-28 | 2025-08-29 | 2025-05-28 | 2025-06-02 | 2025-09-03 | 2025-06-02 | 263 | 263 |
| 000261 |  | Concreto Clase C (f'c=280 kg/cm2) Premezclado - Muros de contencion | 2d | 2025-06-03 | 2025-06-04 | 000263 | 93d | 0d | 5.1.6.12 | 560 | Cronograma Gantt_13 | 2025-06-03 | 2025-09-04 | 2025-06-03 | 2025-06-04 | 2025-09-05 | 2025-06-04 | 261 | 261 |
| 000265 |  | Emboquillado de piedra e=0.20m | 7d | 2025-06-05 | 2025-06-11 | 000261 | 159d | 59d | 5.1.6.16 | 564 | Cronograma Gantt_13 | 2025-06-05 | 2025-11-11 | 2025-06-05 | 2025-06-11 | 2025-11-17 | 2025-06-11 | 265 | 265 |
| 000266 |  | Cama de arena e=0.20m | 1d | 2025-06-05 | 2025-06-05 | 000261, 000255 | 93d | 0d | 5.1.6.17 | 567 | Cronograma Gantt_13 | 2025-06-05 | 2025-09-06 | 2025-06-05 | 2025-06-05 | 2025-09-06 | 2025-06-05 | 266 | 266 |
| 000269 |  | Sello en juntas | 2d | 2025-06-05 | 2025-06-06 | 000261 | 164d | 64d | 5.1.6.20 | 571 | Cronograma Gantt_13 | 2025-06-05 | 2025-11-16 | 2025-06-05 | 2025-06-06 | 2025-11-17 | 2025-06-06 | 269 | 269 |
| 000270 |  | Waterstop (anillos de estanqueidad) | 1d | 2025-06-05 | 2025-06-05 | 000261 | 165d | 65d | 5.1.6.21 | 572 | Cronograma Gantt_13 | 2025-06-05 | 2025-11-17 | 2025-06-05 | 2025-06-05 | 2025-11-17 | 2025-06-05 | 270 | 270 |
| 000267 |  | Tubería HDPE Corrugada Ø=900mm (Suministro e instalación) | 1d | 2025-06-06 | 2025-06-06 | 000266 | 93d | 0d | 5.1.6.18 | 568 | Cronograma Gantt_13 | 2025-06-06 | 2025-09-07 | 2025-06-06 | 2025-06-06 | 2025-09-07 | 2025-06-06 | 267 | 267 |
| 000272 |  | Suministro e Instalación de geotextil | 1d | 2025-06-07 | 2025-06-07 | 000267 | 93d | 0d | 5.1.6.23 | 574 | Cronograma Gantt_13 | 2025-06-07 | 2025-09-08 | 2025-06-07 | 2025-06-07 | 2025-09-08 | 2025-06-07 | 272 | 272 |
| 000268 |  | Compuertas Charnela Ø900 (Suministro e instalacion) | 5d | 2025-06-08 | 2025-06-12 | 000272 | 93d | 0d | 5.1.6.19 | 569 | Cronograma Gantt_13 | 2025-06-08 | 2025-09-09 | 2025-06-08 | 2025-06-12 | 2025-09-13 | 2025-06-12 | 268 | 268 |
| 000271 |  | Pintura bituminosa | 5d | 2025-06-13 | 2025-06-17 | 000268 | 93d | 0d | 5.1.6.22 | 573 | Cronograma Gantt_13 | 2025-06-13 | 2025-09-14 | 2025-06-13 | 2025-06-17 | 2025-09-18 | 2025-06-17 | 271 | 271 |

| ID | WBS | Activity | Duration | Start | Finish | Predecessors | Total float | Free float | MSP Outline Number | MSP Unique ID | MSP Project Name | Imported Early Start | Imported Late Start | Imported Start | Imported Early Finish | Imported Late Finish | Imported Finish | MSP ID | MSP Task Order |
| --- | --- | --- | --- | --- | --- | --- | --- | --- | --- | --- | --- | --- | --- | --- | --- | --- | --- | --- | --- |
|  | 000273 | **Mitigación Ambiental** |  | 2025-05-01 | 2025-05-02 |  |  |  |  |  |  |  |  |  |  |  |  |  |  |
| 000274 |  | Rescate camaron | 2d | 2025-05-01 | 2025-05-02 | 000107 | 0d |  | 5.1.7.1 | 1331 | Cronograma Gantt_13 | 2025-05-01 | 2025-05-01 | 2025-05-01 | 2025-05-02 | 2025-05-02 | 2025-05-02 | 274 | 274 |
|  | 000275 | **DI-PR-51-I** |  | 2025-05-26 | 2025-10-09 |  |  |  |  |  |  |  |  |  |  |  |  |  |  |
|  | 000276 | **Excavaciones** |  | 2025-05-28 | 2025-07-17 |  |  |  |  |  |  |  |  |  |  |  |  |  |  |
| 000277 |  | Desbroce | 3d | 2025-05-28 | 2025-05-30 | 000327 | 0d |  | 5.2.1.1 | 597 | Cronograma Gantt_13 | 2025-05-28 | 2025-05-28 | 2025-05-28 | 2025-05-30 | 2025-05-30 | 2025-05-30 | 277 | 277 |
| 000278 |  | Excavacion de Cimentacion | 19d | 2025-05-31 | 2025-06-18 | 000277 | 0d |  | 5.2.1.2 | 599 | Cronograma Gantt_13 | 2025-05-31 | 2025-05-31 | 2025-05-31 | 2025-06-18 | 2025-06-18 | 2025-06-18 | 278 | 278 |
| 000279 |  | Perfilado y Conformacion de Plataforma de Fundacion | 7d | 2025-06-05 | 2025-06-11 | 000278 SS+5d | 159d | 120d | 5.2.1.3 | 600 | Cronograma Gantt_13 | 2025-06-05 | 2025-11-11 | 2025-06-05 | 2025-06-11 | 2025-11-17 | 2025-06-11 | 279 | 279 |
| 000280 |  | Excavacion de Uña | 17d | 2025-06-05 | 2025-06-21 | 000278 SS+5d | 149d | 110d | 5.2.1.4 | 601 | Cronograma Gantt_13 | 2025-06-05 | 2025-11-01 | 2025-06-05 | 2025-06-21 | 2025-11-17 | 2025-06-21 | 280 | 280 |
| 000282 |  | Conformacion de Material Excedente en DMO | 4d | 2025-06-12 | 2025-06-15 | 000295 | 155d | 116d | 5.2.1.6 | 603 | Cronograma Gantt_13 | 2025-06-12 | 2025-11-14 | 2025-06-12 | 2025-06-15 | 2025-11-17 | 2025-06-15 | 282 | 282 |
| 000281 |  | Conformacion de Material Excedente en DME | 13d | 2025-07-05 | 2025-07-17 | 000297 FS-10d | 123d | 84d | 5.2.1.5 | 602 | Cronograma Gantt_13 | 2025-07-05 | 2025-11-05 | 2025-07-05 | 2025-07-17 | 2025-11-17 | 2025-07-17 | 281 | 281 |
|  | 000283 | **Rellenos** |  | 2025-07-31 | 2025-09-03 |  |  |  |  |  |  |  |  |  |  |  |  |  |  |
| 000285 |  | Relleno con Material Seleccionado (incluye extraccion de material, zarandeo y combinado) | 17d | 2025-07-31 | 2025-08-16 | 000303 FS-15d | 41d | 0d | 5.2.2.2 | 611 | Cronograma Gantt_13 | 2025-07-31 | 2025-09-10 | 2025-07-31 | 2025-08-16 | 2025-09-26 | 2025-08-16 | 285 | 285 |
| 000284 |  | Relleno con Material Granular (incluye extraccion de material, zarandeo y combinado) | 1d | 2025-09-03 | 2025-09-03 | 000299, 000288 | 41d | 2d | 5.2.2.1 | 607 | Cronograma Gantt_13 | 2025-09-03 | 2025-10-14 | 2025-09-03 | 2025-09-03 | 2025-10-14 | 2025-09-03 | 284 | 284 |
|  | 000286 | **Geotextil** |  | 2025-08-17 | 2025-09-02 |  |  |  |  |  |  |  |  |  |  |  |  |  |  |
| 000287 |  | Instalacion de Geotextil 400gr/m2 | 14d | 2025-08-17 | 2025-08-30 | 000305, 000285 | 41d | 0d | 5.2.3.1 | 615 | Cronograma Gantt_13 | 2025-08-17 | 2025-09-27 | 2025-08-17 | 2025-08-30 | 2025-10-10 | 2025-08-30 | 287 | 287 |
| 000288 |  | Zanja de Anclaje | 12d | 2025-08-22 | 2025-09-02 | 000287 SS+5d | 41d | 0d | 5.2.3.2 | 616 | Cronograma Gantt_13 | 2025-08-22 | 2025-10-02 | 2025-08-22 | 2025-09-02 | 2025-10-13 | 2025-09-02 | 288 | 288 |
|  | 000289 | **Colocacion de Roca** |  | 2025-09-06 | 2025-10-09 |  |  |  |  |  |  |  |  |  |  |  |  |  |  |
| 000290 |  | Colocacion de Roca en Uña | 29d | 2025-09-06 | 2025-10-04 | 000301, 000284 | 39d | 0d | 5.2.4.1 | 619 | Cronograma Gantt_13 | 2025-09-06 | 2025-10-15 | 2025-09-06 | 2025-10-04 | 2025-11-12 | 2025-10-04 | 290 | 290 |
| 000291 |  | Colocacion de Roca en Talud | 21d | 2025-09-16 | 2025-10-06 | 000290 SS+10d | 39d | 0d | 5.2.4.2 | 620 | Cronograma Gantt_13 | 2025-09-16 | 2025-10-25 | 2025-09-16 | 2025-10-06 | 2025-11-14 | 2025-10-06 | 291 | 291 |
| 000292 |  | Colocación de Roca en Corona | 9d | 2025-10-01 | 2025-10-09 | 000291 FS-6d | 39d | 0d | 5.2.4.3 | 626 | Cronograma Gantt_13 | 2025-10-01 | 2025-11-09 | 2025-10-01 | 2025-10-09 | 2025-11-17 | 2025-10-09 | 292 | 292 |
|  | 000293 | **Transportes** |  | 2025-05-31 | 2025-09-05 |  |  |  |  |  |  |  |  |  |  |  |  |  |  |
| 000294 |  | Transporte de Material Organico (a DMO) D<=1km | 8d | 2025-05-31 | 2025-06-07 | 000277 | 155d | 0d | 5.2.5.1 | 630 | Cronograma Gantt_13 | 2025-05-31 | 2025-11-02 | 2025-05-31 | 2025-06-07 | 2025-11-09 | 2025-06-07 | 294 | 294 |
| 000295 |  | Transporte de Material Organico (a DMO) D>1km | 12d | 2025-05-31 | 2025-06-11 | 000294 SS | 155d | 0d | 5.2.5.2 | 631 | Cronograma Gantt_13 | 2025-05-31 | 2025-11-02 | 2025-05-31 | 2025-06-11 | 2025-11-13 | 2025-06-11 | 295 | 295 |
| 000296 |  | Transporte de Material Excedente D<=1km | 20d | 2025-06-05 | 2025-06-24 | 000278 SS+5d | 39d | 0d | 5.2.5.3 | 632 | Cronograma Gantt_13 | 2025-06-05 | 2025-07-14 | 2025-06-05 | 2025-06-24 | 2025-08-02 | 2025-06-24 | 296 | 296 |
| 000297 |  | Transporte de Material Excedente D>1km | 40d | 2025-06-05 | 2025-07-14 | 000296 SS | 39d | 0d | 5.2.5.4 | 633 | Cronograma Gantt_13 | 2025-06-05 | 2025-07-14 | 2025-06-05 | 2025-07-14 | 2025-08-22 | 2025-07-14 | 297 | 297 |
| 000302 |  | Transporte de Material de Prestamo Cantera de Rio (Cuerpo de Terraplen) D<=1km | 28d | 2025-06-20 | 2025-07-17 | 000297 FS-25d | 39d | 0d | 5.2.5.9 | 638 | Cronograma Gantt_13 | 2025-06-20 | 2025-07-29 | 2025-06-20 | 2025-07-17 | 2025-08-25 | 2025-07-17 | 302 | 302 |
| 000303 |  | Transporte de Material de Prestamo Cantera de Rio (Cuerpo de Terraplen) D>1km | 56d | 2025-06-20 | 2025-08-14 | 000302 SS | 39d | 0d | 5.2.5.10 | 639 | Cronograma Gantt_13 | 2025-06-20 | 2025-07-29 | 2025-06-20 | 2025-08-14 | 2025-09-22 | 2025-08-14 | 303 | 303 |
| 000300 |  | Transporte de Roca D<=1km | 17d | 2025-08-05 | 2025-08-21 | 000303 FS-10d | 39d | 0d | 5.2.5.7 | 636 | Cronograma Gantt_13 | 2025-08-05 | 2025-09-13 | 2025-08-05 | 2025-08-21 | 2025-09-29 | 2025-08-21 | 300 | 300 |
| 000301 |  | Transporte de Roca D>1km | 32d | 2025-08-05 | 2025-09-05 | 000300 SS | 39d | 0d | 5.2.5.8 | 637 | Cronograma Gantt_13 | 2025-08-05 | 2025-09-13 | 2025-08-05 | 2025-09-05 | 2025-10-14 | 2025-09-05 | 301 | 301 |
| 000304 |  | Transporte de Material Seleccionado para Zanja D<=1km | 1d | 2025-08-14 | 2025-08-14 | 000303 FS-1d | 42d | 0d | 5.2.5.11 | 640 | Cronograma Gantt_13 | 2025-08-14 | 2025-09-25 | 2025-08-14 | 2025-08-14 | 2025-09-25 | 2025-08-14 | 304 | 304 |
| 000305 |  | Transporte de Material Seleccionado para Zanja D>1km | 1d | 2025-08-15 | 2025-08-15 | 000304 | 42d | 0d | 5.2.5.12 | 641 | Cronograma Gantt_13 | 2025-08-15 | 2025-09-26 | 2025-08-15 | 2025-08-15 | 2025-09-26 | 2025-08-15 | 305 | 305 |
| 000298 |  | Transporte de Material de Prestamo (Afirmado) D<=1km | 7d | 2025-08-16 | 2025-08-22 | 000305 | 47d | 0d | 5.2.5.5 | 634 | Cronograma Gantt_13 | 2025-08-16 | 2025-10-02 | 2025-08-16 | 2025-08-22 | 2025-10-08 | 2025-08-22 | 298 | 298 |
| 000299 |  | Transporte de Material de Prestamo (Afirmado) D>1km | 12d | 2025-08-16 | 2025-08-27 | 000298 SS | 47d | 6d | 5.2.5.6 | 635 | Cronograma Gantt_13 | 2025-08-16 | 2025-10-02 | 2025-08-16 | 2025-08-27 | 2025-10-13 | 2025-08-27 | 299 | 299 |

| ID | WBS | Activity | Duration | Start | Finish | Predecessors | Total float | Free float | MSP Outline Number | MSP Unique ID | MSP Project Name | Imported Early Start | Imported Late Start | Imported Start | Imported Early Finish | Imported Late Finish | Imported Finish | MSP ID | MSP Task Order |
| --- | --- | --- | --- | --- | --- | --- | --- | --- | --- | --- | --- | --- | --- | --- | --- | --- | --- | --- | --- |
|  | 000306 | **Obras Civiles (Interferencias)** |  | 2025-06-18 | 2025-08-16 |  |  |  |  |  |  |  |  |  |  |  |  |  |  |
| 000307 |  | Trazo y replanteo de interferencia | 2d | 2025-06-18 | 2025-06-19 | 000271 | 93d | 0d | 5.2.6.1 | 643 | Cronograma Gantt_13 | 2025-06-18 | 2025-09-19 | 2025-06-18 | 2025-06-19 | 2025-09-20 | 2025-06-19 | 307 | 307 |
| 000310 |  | Limpieza de terreno manual | 13d | 2025-06-20 | 2025-07-02 | 000307 | 93d | 0d | 5.2.6.4 | 646 | Cronograma Gantt_13 | 2025-06-20 | 2025-09-21 | 2025-06-20 | 2025-07-02 | 2025-10-03 | 2025-07-02 | 310 | 310 |
| 000311 |  | Excavaciones no clasificada para estructuras | 1d | 2025-07-03 | 2025-07-03 | 000310 | 93d | 0d | 5.2.6.5 | 647 | Cronograma Gantt_13 | 2025-07-03 | 2025-10-04 | 2025-07-03 | 2025-07-03 | 2025-10-04 | 2025-07-03 | 311 | 311 |
| 000312 |  | Excavacion no clasificada de zanja | 5d | 2025-07-03 | 2025-07-07 | 000310 | 126d | 0d | 5.2.6.6 | 648 | Cronograma Gantt_13 | 2025-07-03 | 2025-11-06 | 2025-07-03 | 2025-07-07 | 2025-11-10 | 2025-07-07 | 312 | 312 |
| 000313 |  | Relleno estructural | 5d | 2025-07-04 | 2025-07-08 | 000311 | 93d | 0d | 5.2.6.7 | 649 | Cronograma Gantt_13 | 2025-07-04 | 2025-10-05 | 2025-07-04 | 2025-07-08 | 2025-10-09 | 2025-07-08 | 313 | 313 |
| 000308 |  | Desvío provisional con tubería | 2d | 2025-07-08 | 2025-07-09 | 000312 | 131d | 92d | 5.2.6.2 | 644 | Cronograma Gantt_13 | 2025-07-08 | 2025-11-16 | 2025-07-08 | 2025-07-09 | 2025-11-17 | 2025-07-09 | 308 | 308 |
| 000309 |  | Desvío provisional en tierras | 7d | 2025-07-08 | 2025-07-14 | 000312 | 126d | 87d | 5.2.6.3 | 645 | Cronograma Gantt_13 | 2025-07-08 | 2025-11-11 | 2025-07-08 | 2025-07-14 | 2025-11-17 | 2025-07-14 | 309 | 309 |
| 000314 |  | Colocación de roca en uña (Alcantarillas) | 1d | 2025-07-09 | 2025-07-09 | 000313 | 131d | 92d | 5.2.6.8 | 651 | Cronograma Gantt_13 | 2025-07-09 | 2025-11-17 | 2025-07-09 | 2025-07-09 | 2025-11-17 | 2025-07-09 | 314 | 314 |
| 000315 |  | Concreto de Nivelacion (f'c=100 kg/cm2) | 1d | 2025-07-09 | 2025-07-09 | 000313 | 93d | 0d | 5.2.6.9 | 652 | Cronograma Gantt_13 | 2025-07-09 | 2025-10-10 | 2025-07-09 | 2025-07-09 | 2025-10-10 | 2025-07-09 | 315 | 315 |
| 000316 |  | Concreto Clase C (f'c=280 kg/cm2) Premezclado - Cimientos reforzados | 1d | 2025-07-10 | 2025-07-10 | 000315 | 93d | 0d | 5.2.6.10 | 654 | Cronograma Gantt_13 | 2025-07-10 | 2025-10-11 | 2025-07-10 | 2025-07-10 | 2025-10-11 | 2025-07-10 | 316 | 316 |
| 000320 |  | Acero de refuerzo f'y=4200kg/cm2 | 9d | 2025-07-11 | 2025-07-19 | 000316 | 93d | 0d | 5.2.6.14 | 658 | Cronograma Gantt_13 | 2025-07-11 | 2025-10-12 | 2025-07-11 | 2025-07-19 | 2025-10-20 | 2025-07-19 | 320 | 320 |
| 000318 |  | Encofrado y Desencofrado Caravista | 9d | 2025-07-20 | 2025-07-28 | 000320 | 93d | 0d | 5.2.6.12 | 656 | Cronograma Gantt_13 | 2025-07-20 | 2025-10-21 | 2025-07-20 | 2025-07-28 | 2025-10-29 | 2025-07-28 | 318 | 318 |
| 000319 |  | Encofrado y Desencofrado Cara Oculta | 7d | 2025-07-20 | 2025-07-26 | 000320 | 114d | 75d | 5.2.6.13 | 657 | Cronograma Gantt_13 | 2025-07-20 | 2025-11-11 | 2025-07-20 | 2025-07-26 | 2025-11-17 | 2025-07-26 | 319 | 319 |
| 000317 |  | Concreto Clase C (f'c=280 kg/cm2) Premezclado - Muros de contencion | 1d | 2025-07-29 | 2025-07-29 | 000318 | 93d | 0d | 5.2.6.11 | 655 | Cronograma Gantt_13 | 2025-07-29 | 2025-10-30 | 2025-07-29 | 2025-07-29 | 2025-10-30 | 2025-07-29 | 317 | 317 |
| 000321 |  | Emboquillado de piedra e=0.20m | 18d | 2025-07-30 | 2025-08-16 | 000317 | 93d | 54d | 5.2.6.15 | 659 | Cronograma Gantt_13 | 2025-07-30 | 2025-10-31 | 2025-07-30 | 2025-08-16 | 2025-11-17 | 2025-08-16 | 321 | 321 |
| 000322 |  | Emboquillado de piedra e=0.30m | 1d | 2025-07-30 | 2025-07-30 | 000317 | 110d | 71d | 5.2.6.16 | 660 | Cronograma Gantt_13 | 2025-07-30 | 2025-11-17 | 2025-07-30 | 2025-07-30 | 2025-11-17 | 2025-07-30 | 322 | 322 |
| 000323 |  | Emboquillado de piedra e=0.50m | 2d | 2025-07-30 | 2025-07-31 | 000317 | 109d | 70d | 5.2.6.17 | 661 | Cronograma Gantt_13 | 2025-07-30 | 2025-11-16 | 2025-07-30 | 2025-07-31 | 2025-11-17 | 2025-07-31 | 323 | 323 |
| 000324 |  | Sello en juntas | 4d | 2025-07-30 | 2025-08-02 | 000317 | 107d | 68d | 5.2.6.18 | 666 | Cronograma Gantt_13 | 2025-07-30 | 2025-11-14 | 2025-07-30 | 2025-08-02 | 2025-11-17 | 2025-08-02 | 324 | 324 |
| 000325 |  | Pintura bituminosa | 5d | 2025-07-30 | 2025-08-03 | 000317 | 106d | 67d | 5.2.6.19 | 668 | Cronograma Gantt_13 | 2025-07-30 | 2025-11-13 | 2025-07-30 | 2025-08-03 | 2025-11-17 | 2025-08-03 | 325 | 325 |
|  | 000326 | **Mitigación Ambiental** |  | 2025-05-26 | 2025-05-27 |  |  |  |  |  |  |  |  |  |  |  |  |  |  |
| 000327 |  | Rescate camaron | 2d | 2025-05-26 | 2025-05-27 | 000017 | 0d |  | 5.2.7.1 | 1333 | Cronograma Gantt_13 | 2025-05-26 | 2025-05-26 | 2025-05-26 | 2025-05-27 | 2025-05-27 | 2025-05-27 | 327 | 327 |
|  | 000328 | **DI-PR-47bis-D / DE-PR-49bis-D** |  | 2025-06-19 | 2025-11-17 |  |  |  |  |  |  |  |  |  |  |  |  |  |  |
|  | 000329 | **Excavaciones** |  | 2025-06-21 | 2025-11-17 |  |  |  |  |  |  |  |  |  |  |  |  |  |  |
| 000330 |  | Desbroce | 3d | 2025-06-21 | 2025-06-23 | 000367 | 0d |  | 5.3.1.1 | 692 | Cronograma Gantt_13 | 2025-06-21 | 2025-06-21 | 2025-06-21 | 2025-06-23 | 2025-06-23 | 2025-06-23 | 330 | 330 |
| 000331 |  | Remocion de Dique Existente | 3d | 2025-06-24 | 2025-06-26 | 000330 | 0d |  | 5.3.1.2 | 693 | Cronograma Gantt_13 | 2025-06-24 | 2025-06-24 | 2025-06-24 | 2025-06-26 | 2025-06-26 | 2025-06-26 | 331 | 331 |
| 000332 |  | Excavacion de Cimentacion | 12d | 2025-06-27 | 2025-07-08 | 000331 | 0d |  | 5.3.1.3 | 694 | Cronograma Gantt_13 | 2025-06-27 | 2025-06-27 | 2025-06-27 | 2025-07-08 | 2025-07-08 | 2025-07-08 | 332 | 332 |
| 000333 |  | Perfilado y Conformacion de Plataforma de Fundacion | 8d | 2025-07-04 | 2025-07-11 | 000332 FS-5d | 125d | 0d | 5.3.1.4 | 695 | Cronograma Gantt_13 | 2025-07-04 | 2025-11-06 | 2025-07-04 | 2025-07-11 | 2025-11-13 | 2025-07-11 | 333 | 333 |
| 000337 |  | Excavacion Localizada - Sobreexcavacion | 7d | 2025-07-04 | 2025-07-10 | 000332 FS-5d | 130d | 113d | 5.3.1.8 | 699 | Cronograma Gantt_13 | 2025-07-04 | 2025-11-11 | 2025-07-04 | 2025-07-10 | 2025-11-17 | 2025-07-10 | 337 | 337 |
| 000334 |  | Excavacion de Uña | 9d | 2025-07-07 | 2025-07-15 | 000333 FS-5d | 125d | 108d | 5.3.1.5 | 696 | Cronograma Gantt_13 | 2025-07-07 | 2025-11-09 | 2025-07-07 | 2025-07-15 | 2025-11-17 | 2025-07-15 | 334 | 334 |
| 000336 |  | Conformacion de Material Excedente en DMO | 4d | 2025-07-09 | 2025-07-12 | 000355 | 128d | 111d | 5.3.1.7 | 698 | Cronograma Gantt_13 | 2025-07-09 | 2025-11-14 | 2025-07-09 | 2025-07-12 | 2025-11-17 | 2025-07-12 | 336 | 336 |
| 000335 |  | Conformacion de Material Excedente en DME | 12d | 2025-08-03 | 2025-08-14 | 000357 | 95d | 78d | 5.3.1.6 | 697 | Cronograma Gantt_13 | 2025-08-03 | 2025-11-06 | 2025-08-03 | 2025-08-14 | 2025-11-17 | 2025-08-14 | 335 | 335 |
| 000338 |  | Descolmatación | 17d | 2025-11-01 | 2025-11-17 | 000351 | 0d |  | 5.3.1.9 | 1345 | Cronograma Gantt_13 | 2025-11-01 | 2025-11-01 | 2025-11-01 | 2025-11-17 | 2025-11-17 | 2025-11-17 | 338 | 338 |

| ID | WBS | Activity | Duration | Start | Finish | Predecessors | Total float | Free float | MSP Outline Number | MSP Unique ID | MSP Project Name | Imported Early Start | Imported Late Start | Imported Start | Imported Early Finish | Imported Late Finish | Imported Finish | MSP ID | MSP Task Order |
| --- | --- | --- | --- | --- | --- | --- | --- | --- | --- | --- | --- | --- | --- | --- | --- | --- | --- | --- | --- |
|  | 000339 | **Rellenos** |  | 2025-08-21 | 2025-10-22 |  |  |  |  |  |  |  |  |  |  |  |  |  |  |
| 000340 |  | Relleno con Material Granular (incluye extraccion de material, zarandeo y combinado) | 24d | 2025-08-21 | 2025-09-13 | 000363 FS-10d | 0d |  | 5.3.2.1 | 702 | Cronograma Gantt_13 | 2025-08-21 | 2025-08-21 | 2025-08-21 | 2025-09-13 | 2025-09-13 | 2025-09-13 | 340 | 340 |
| 000344 |  | Relleno con Material Seleccionado (incluye extraccion de material, zarandeo y combinado) | 7d | 2025-08-31 | 2025-09-06 | 000363 | 72d | 55d | 5.3.2.5 | 706 | Cronograma Gantt_13 | 2025-08-31 | 2025-11-11 | 2025-08-31 | 2025-09-06 | 2025-11-17 | 2025-09-06 | 344 | 344 |
| 000343 |  | Perfilado de Talud Dique | 6d | 2025-09-14 | 2025-09-19 | 000340 | 0d |  | 5.3.2.4 | 705 | Cronograma Gantt_13 | 2025-09-14 | 2025-09-14 | 2025-09-14 | 2025-09-19 | 2025-09-19 | 2025-09-19 | 343 | 343 |
| 000342 |  | Relleno Afirmado | 2d | 2025-10-10 | 2025-10-11 | 000359, 000348 | 37d | 20d | 5.3.2.3 | 704 | Cronograma Gantt_13 | 2025-10-10 | 2025-11-16 | 2025-10-10 | 2025-10-11 | 2025-11-17 | 2025-10-11 | 342 | 342 |
| 000341 |  | Relleno sin Compactar | 5d | 2025-10-18 | 2025-10-22 | 000350 | 26d | 9d | 5.3.2.2 | 703 | Cronograma Gantt_13 | 2025-10-18 | 2025-11-13 | 2025-10-18 | 2025-10-22 | 2025-11-17 | 2025-10-22 | 341 | 341 |
| 000345 |  | Grava para Drenaje | 2d | 2025-10-18 | 2025-10-19 | 000350 | 29d | 12d | 5.3.2.6 | 707 | Cronograma Gantt_13 | 2025-10-18 | 2025-11-16 | 2025-10-18 | 2025-10-19 | 2025-11-17 | 2025-10-19 | 345 | 345 |
|  | 000346 | **Geotextil** |  | 2025-09-20 | 2025-10-09 |  |  |  |  |  |  |  |  |  |  |  |  |  |  |
| 000347 |  | Instalacion de Geotextil 400gr/m2 | 12d | 2025-09-20 | 2025-10-01 | 000343 | 0d |  | 5.3.3.1 | 710 | Cronograma Gantt_13 | 2025-09-20 | 2025-09-20 | 2025-09-20 | 2025-10-01 | 2025-10-01 | 2025-10-01 | 347 | 347 |
| 000348 |  | Zanja de Anclaje | 13d | 2025-09-27 | 2025-10-09 | 000365, 000347 FS-5d | 37d | 0d | 5.3.3.2 | 711 | Cronograma Gantt_13 | 2025-09-27 | 2025-11-03 | 2025-09-27 | 2025-10-09 | 2025-11-15 | 2025-10-09 | 348 | 348 |
|  | 000349 | **Colocacion de Roca** |  | 2025-06-27 | 2025-10-31 |  |  |  |  |  |  |  |  |  |  |  |  |  |  |
| 000352 |  | Extraccion de Rocas Reutilizables | 7d | 2025-06-27 | 2025-07-03 | 000331 | 137d | 120d | 5.3.4.3 | 716 | Cronograma Gantt_13 | 2025-06-27 | 2025-11-11 | 2025-06-27 | 2025-07-03 | 2025-11-17 | 2025-07-03 | 352 | 352 |
| 000350 |  | Colocacion de Roca en Uña | 16d | 2025-10-02 | 2025-10-17 | 000347 | 0d |  | 5.3.4.1 | 714 | Cronograma Gantt_13 | 2025-10-02 | 2025-10-02 | 2025-10-02 | 2025-10-17 | 2025-10-17 | 2025-10-17 | 350 | 350 |
| 000351 |  | Colocacion de Roca en Talud | 25d | 2025-10-07 | 2025-10-31 | 000361, 000350 SS+5d | 0d |  | 5.3.4.2 | 715 | Cronograma Gantt_13 | 2025-10-07 | 2025-10-07 | 2025-10-07 | 2025-10-31 | 2025-10-31 | 2025-10-31 | 351 | 351 |
|  | 000353 | **Transportes** |  | 2025-06-24 | 2025-09-27 |  |  |  |  |  |  |  |  |  |  |  |  |  |  |
| 000354 |  | Transporte de Material Organico (a DMO) D<=1km | 8d | 2025-06-24 | 2025-07-01 | 000330 | 128d | 0d | 5.3.5.1 | 725 | Cronograma Gantt_13 | 2025-06-24 | 2025-10-30 | 2025-06-24 | 2025-07-01 | 2025-11-06 | 2025-07-01 | 354 | 354 |
| 000355 |  | Transporte de Material Organico (a DMO) D>1km | 15d | 2025-06-24 | 2025-07-08 | 000354 SS | 128d | 0d | 5.3.5.2 | 726 | Cronograma Gantt_13 | 2025-06-24 | 2025-10-30 | 2025-06-24 | 2025-07-08 | 2025-11-13 | 2025-07-08 | 355 | 355 |
| 000356 |  | Transporte de Material Excedente D<=1km | 25d | 2025-07-02 | 2025-07-26 | 000332 SS+5d | 0d |  | 5.3.5.3 | 727 | Cronograma Gantt_13 | 2025-07-02 | 2025-07-02 | 2025-07-02 | 2025-07-26 | 2025-07-26 | 2025-07-26 | 356 | 356 |
| 000357 |  | Transporte de Material Excedente D>1km | 32d | 2025-07-02 | 2025-08-02 | 000356 SS | 0d |  | 5.3.5.4 | 728 | Cronograma Gantt_13 | 2025-07-02 | 2025-07-02 | 2025-07-02 | 2025-08-02 | 2025-08-02 | 2025-08-02 | 357 | 357 |
| 000362 |  | Transporte de Material de Prestamo Cantera de Rio (Cuerpo de Terraplen) D<=1km | 29d | 2025-07-29 | 2025-08-26 | 000357 FS-5d | 0d |  | 5.3.5.9 | 733 | Cronograma Gantt_13 | 2025-07-29 | 2025-07-29 | 2025-07-29 | 2025-08-26 | 2025-08-26 | 2025-08-26 | 362 | 362 |
| 000363 |  | Transporte de Material de Prestamo Cantera de Rio (Cuerpo de Terraplen) D>1km | 33d | 2025-07-29 | 2025-08-30 | 000362 SS | 0d |  | 5.3.5.10 | 734 | Cronograma Gantt_13 | 2025-07-29 | 2025-07-29 | 2025-07-29 | 2025-08-30 | 2025-08-30 | 2025-08-30 | 363 | 363 |
| 000360 |  | Transporte de Roca D<=1km | 33d | 2025-08-26 | 2025-09-27 | 000363 FS-5d | 11d | 0d | 5.3.5.7 | 731 | Cronograma Gantt_13 | 2025-08-26 | 2025-09-06 | 2025-08-26 | 2025-09-27 | 2025-10-08 | 2025-09-27 | 360 | 360 |
| 000361 |  | Transporte de Roca D>1km | 31d | 2025-08-26 | 2025-09-25 | 000360 SS | 11d |  | 5.3.5.8 | 732 | Cronograma Gantt_13 | 2025-08-26 | 2025-09-06 | 2025-08-26 | 2025-09-25 | 2025-10-06 | 2025-09-25 | 361 | 361 |
| 000364 |  | Transporte de Material Seleccionado para Zanja D<=1km | 1d | 2025-08-31 | 2025-08-31 | 000363 | 53d | 0d | 5.3.5.11 | 735 | Cronograma Gantt_13 | 2025-08-31 | 2025-10-23 | 2025-08-31 | 2025-08-31 | 2025-10-23 | 2025-08-31 | 364 | 364 |
| 000365 |  | Transporte de Material Seleccionado para Zanja D>1km | 1d | 2025-08-31 | 2025-08-31 | 000364 SS | 53d | 0d | 5.3.5.12 | 736 | Cronograma Gantt_13 | 2025-08-31 | 2025-10-23 | 2025-08-31 | 2025-08-31 | 2025-10-23 | 2025-08-31 | 365 | 365 |
| 000358 |  | Transporte de Material de Prestamo (Afirmado) D<=1km | 19d | 2025-09-01 | 2025-09-19 | 000365 | 53d | 0d | 5.3.5.5 | 729 | Cronograma Gantt_13 | 2025-09-01 | 2025-10-24 | 2025-09-01 | 2025-09-19 | 2025-11-11 | 2025-09-19 | 358 | 358 |
| 000359 |  | Transporte de Material de Prestamo (Afirmado) D>1km | 23d | 2025-09-01 | 2025-09-23 | 000358 SS | 53d | 16d | 5.3.5.6 | 730 | Cronograma Gantt_13 | 2025-09-01 | 2025-10-24 | 2025-09-01 | 2025-09-23 | 2025-11-15 | 2025-09-23 | 359 | 359 |

| ID | WBS | Activity | Duration | Start | Finish | Predecessors | Total float | Free float | Constraint | MSP Outline Number | MSP Unique ID | MSP Project Name | Imported Early Start | Imported Late Start | Imported Start | Imported Early Finish | Imported Late Finish | Imported Finish | MSP ID | MSP Task Order |
| --- | --- | --- | --- | --- | --- | --- | --- | --- | --- | --- | --- | --- | --- | --- | --- | --- | --- | --- | --- | --- |
|  | 000366 | **Mitigación Ambiental** |  | 2025-06-19 | 2025-06-20 |  |  |  |  |  |  |  |  |  |  |  |  |  |  |  |
| 000367 |  | Rescate camaron | 2d | 2025-06-19 | 2025-06-20 | 000019 | 0d |  |  | 5.3.6.1 | 1335 | Cronograma Gantt_13 | 2025-06-19 | 2025-06-19 | 2025-06-19 | 2025-06-20 | 2025-06-20 | 2025-06-20 | 367 | 367 |
|  | 000368 | **DI-PR-40A-D / DI-PR-40B-D** |  | 2025-07-09 | 2025-10-24 |  |  |  |  |  |  |  |  |  |  |  |  |  |  |  |
|  | 000369 | **Excavaciones** |  | 2025-07-11 | 2025-08-31 |  |  |  |  |  |  |  |  |  |  |  |  |  |  |  |
| 000370 |  | Desbroce | 1d | 2025-07-11 | 2025-07-11 | 000413 | 2d | 0d |  | 5.4.1.1 | 884 | Cronograma Gantt_13 | 2025-07-11 | 2025-07-13 | 2025-07-11 | 2025-07-11 | 2025-07-13 | 2025-07-11 | 370 | 370 |
| 000371 |  | Remocion de Dique Existente | 3d | 2025-07-12 | 2025-07-14 | 000370 | 2d | 0d |  | 5.4.1.2 | 885 | Cronograma Gantt_13 | 2025-07-12 | 2025-07-14 | 2025-07-12 | 2025-07-14 | 2025-07-16 | 2025-07-14 | 371 | 371 |
| 000372 |  | Excavacion de Cimentacion | 20d | 2025-07-15 | 2025-08-03 | 000371 | 2d | 0d |  | 5.4.1.3 | 886 | Cronograma Gantt_13 | 2025-07-15 | 2025-07-17 | 2025-07-15 | 2025-08-03 | 2025-08-05 | 2025-08-03 | 372 | 372 |
| 000376 |  | Conformacion de Material Excedente en DMO | 2d | 2025-07-21 | 2025-07-22 | 000397 | 118d | 94d |  | 5.4.1.7 | 890 | Cronograma Gantt_13 | 2025-07-21 | 2025-11-16 | 2025-07-21 | 2025-07-22 | 2025-11-17 | 2025-07-22 | 376 | 376 |
| 000373 |  | Perfilado y Conformacion de Plataforma de Fundacion | 3d | 2025-08-04 | 2025-08-06 | 000372 | 103d | 79d |  | 5.4.1.4 | 887 | Cronograma Gantt_13 | 2025-08-04 | 2025-11-15 | 2025-08-04 | 2025-08-06 | 2025-11-17 | 2025-08-06 | 373 | 373 |
| 000374 |  | Excavacion de Uña | 12d | 2025-08-04 | 2025-08-15 | 000372 | 35d | 0d |  | 5.4.1.5 | 888 | Cronograma Gantt_13 | 2025-08-04 | 2025-09-08 | 2025-08-04 | 2025-08-15 | 2025-09-19 | 2025-08-15 | 374 | 374 |
| 000375 |  | Conformacion de Material Excedente en DME | 12d | 2025-08-20 | 2025-08-31 | 000399 | 78d | 54d |  | 5.4.1.6 | 889 | Cronograma Gantt_13 | 2025-08-20 | 2025-11-06 | 2025-08-20 | 2025-08-31 | 2025-11-17 | 2025-08-31 | 375 | 375 |
|  | 000377 | **Rellenos** |  | 2025-08-23 | 2025-09-24 |  |  |  |  |  |  |  |  |  |  |  |  |  |  |  |
| 000381 |  | Relleno con Material Seleccionado (incluye extraccion de material, zarandeo y combinado) | 8d | 2025-08-23 | 2025-08-30 | 000405 FS-5d | 24d | 0d |  | 5.4.2.4 | 1317 | Cronograma Gantt_13 | 2025-08-23 | 2025-09-16 | 2025-08-23 | 2025-08-30 | 2025-09-23 | 2025-08-30 | 381 | 381 |
| 000378 |  | Relleno con Material Granular (incluye extraccion de material, zarandeo y combinado) | 2d | 2025-08-28 | 2025-08-29 | 000405 | 80d | 56d |  | 5.4.2.1 | 1314 | Cronograma Gantt_13 | 2025-08-28 | 2025-11-16 | 2025-08-28 | 2025-08-29 | 2025-11-17 | 2025-08-29 | 378 | 378 |
| 000380 |  | Perfilado de Talud Dique | 1d | 2025-08-31 | 2025-08-31 | 000381 | 24d | 0d |  | 5.4.2.3 | 1316 | Cronograma Gantt_13 | 2025-08-31 | 2025-09-24 | 2025-08-31 | 2025-08-31 | 2025-09-24 | 2025-08-31 | 380 | 380 |
| 000382 |  | Grava para Drenaje | 1d | 2025-09-01 | 2025-09-01 | 000380 | 77d | 53d | start on or after 2024-06-13 | 5.4.2.5 | 1318 | Cronograma Gantt_13 | 2025-09-01 | 2025-11-17 | 2025-09-01 | 2025-09-01 | 2025-11-17 | 2025-09-01 | 382 | 382 |
| 000379 |  | Relleno Afirmado | 1d | 2025-09-24 | 2025-09-24 | 000401, 000385 | 54d | 30d |  | 5.4.2.2 | 1315 | Cronograma Gantt_13 | 2025-09-24 | 2025-11-17 | 2025-09-24 | 2025-09-24 | 2025-11-17 | 2025-09-24 | 379 | 379 |
|  | 000383 | **Geotextil** |  | 2025-09-01 | 2025-09-23 |  |  |  |  |  |  |  |  |  |  |  |  |  |  |  |
| 000384 |  | Instalacion de Geotextil 400gr/m2 | 20d | 2025-09-01 | 2025-09-20 | 000380 | 24d | 0d |  | 5.4.3.1 | 902 | Cronograma Gantt_13 | 2025-09-01 | 2025-09-25 | 2025-09-01 | 2025-09-20 | 2025-10-14 | 2025-09-20 | 384 | 384 |
| 000385 |  | Zanja de Anclaje | 13d | 2025-09-11 | 2025-09-23 | 000407, 000384 SS+10d | 54d | 0d |  | 5.4.3.2 | 903 | Cronograma Gantt_13 | 2025-09-11 | 2025-11-04 | 2025-09-11 | 2025-09-23 | 2025-11-16 | 2025-09-23 | 385 | 385 |
|  | 000386 | **Colocacion de Roca** |  | 2025-07-15 | 2025-10-24 |  |  |  |  |  |  |  |  |  |  |  |  |  |  |  |
| 000389 |  | Extraccion de Rocas Reutilizables | 7d | 2025-07-15 | 2025-07-21 | 000371 | 119d | 95d |  | 5.4.4.3 | 908 | Cronograma Gantt_13 | 2025-07-15 | 2025-11-11 | 2025-07-15 | 2025-07-21 | 2025-11-17 | 2025-07-21 | 389 | 389 |
| 000392 |  | Desmontaje y Recolocacion de Enrocado | 2d | 2025-08-16 | 2025-08-17 | 000374 | 35d | 0d |  | 5.4.4.6 | 912 | Cronograma Gantt_13 | 2025-08-16 | 2025-09-20 | 2025-08-16 | 2025-08-17 | 2025-09-21 | 2025-08-17 | 392 | 392 |
| 000394 |  | Rehabilitacion de Enrocados de Proteccion Existentes | 37d | 2025-08-18 | 2025-09-23 | 000392 | 35d | 0d |  | 5.4.4.8 | 915 | Cronograma Gantt_13 | 2025-08-18 | 2025-09-22 | 2025-08-18 | 2025-09-23 | 2025-10-28 | 2025-09-23 | 394 | 394 |
| 000387 |  | Colocacion de Roca en Uña | 20d | 2025-09-21 | 2025-10-10 | 000403, 000384 | 24d | 0d |  | 5.4.4.1 | 906 | Cronograma Gantt_13 | 2025-09-21 | 2025-10-15 | 2025-09-21 | 2025-10-10 | 2025-11-03 | 2025-10-10 | 387 | 387 |
| 000391 |  | Malla Gavion de 1m x 1m x 5m | 19d | 2025-09-24 | 2025-10-12 | 000394 | 35d | 0d |  | 5.4.4.5 | 910 | Cronograma Gantt_13 | 2025-09-24 | 2025-10-29 | 2025-09-24 | 2025-10-12 | 2025-11-16 | 2025-10-12 | 391 | 391 |
| 000388 |  | Colocacion de Roca en Talud | 19d | 2025-09-26 | 2025-10-14 | 000387 SS+5d | 24d | 0d |  | 5.4.4.2 | 907 | Cronograma Gantt_13 | 2025-09-26 | 2025-10-20 | 2025-09-26 | 2025-10-14 | 2025-11-07 | 2025-10-14 | 388 | 388 |
| 000390 |  | Proteccion de Talud con Colchon Reno 6m Largo x e=0.30cm | 1d | 2025-10-13 | 2025-10-13 | 000391 | 35d | 11d |  | 5.4.4.4 | 909 | Cronograma Gantt_13 | 2025-10-13 | 2025-11-17 | 2025-10-13 | 2025-10-13 | 2025-11-17 | 2025-10-13 | 390 | 390 |
| 000393 |  | Colocación de Roca en Corona | 10d | 2025-10-15 | 2025-10-24 | 000388 | 24d | 0d |  | 5.4.4.7 | 913 | Cronograma Gantt_13 | 2025-10-15 | 2025-11-08 | 2025-10-15 | 2025-10-24 | 2025-11-17 | 2025-10-24 | 393 | 393 |

| ID | WBS | Activity | Duration | Start | Finish | Predecessors | Total float | Free float | MSP Outline Number | MSP Unique ID | MSP Project Name | Imported Early Start | Imported Late Start | Imported Start | Imported Early Finish | Imported Late Finish | Imported Finish | MSP ID | MSP Task Order |
| --- | --- | --- | --- | --- | --- | --- | --- | --- | --- | --- | --- | --- | --- | --- | --- | --- | --- | --- | --- |
|  | 000395 | **Transportes** |  | 2025-07-12 | 2025-09-05 |  |  |  |  |  |  |  |  |  |  |  |  |  |  |
| 000396 |  | Transporte de Material Organico (a DMO) D<=1km | 5d | 2025-07-12 | 2025-07-16 | 000370 | 118d | 0d | 5.4.5.1 | 917 | Cronograma Gantt_13 | 2025-07-12 | 2025-11-07 | 2025-07-12 | 2025-07-16 | 2025-11-11 | 2025-07-16 | 396 | 396 |
| 000397 |  | Transporte de Material Organico (a DMO) D>1km | 9d | 2025-07-12 | 2025-07-20 | 000396 SS | 118d | 0d | 5.4.5.2 | 918 | Cronograma Gantt_13 | 2025-07-12 | 2025-11-07 | 2025-07-12 | 2025-07-20 | 2025-11-15 | 2025-07-20 | 397 | 397 |
| 000398 |  | Transporte de Material Excedente D<=1km | 23d | 2025-07-25 | 2025-08-16 | 000372 FS-10d | 24d | 0d | 5.4.5.3 | 919 | Cronograma Gantt_13 | 2025-07-25 | 2025-08-18 | 2025-07-25 | 2025-08-16 | 2025-09-09 | 2025-08-16 | 398 | 398 |
| 000399 |  | Transporte de Material Excedente D>1km | 15d | 2025-08-05 | 2025-08-19 | 000398 FS-12d | 78d | 0d | 5.4.5.4 | 920 | Cronograma Gantt_13 | 2025-08-05 | 2025-10-22 | 2025-08-05 | 2025-08-19 | 2025-11-05 | 2025-08-19 | 399 | 399 |
| 000404 |  | Transporte de Material de Prestamo Cantera de Rio (Cuerpo de Terraplen) D<=1km | 9d | 2025-08-12 | 2025-08-20 | 000398 FS-5d | 24d | 0d | 5.4.5.9 | 925 | Cronograma Gantt_13 | 2025-08-12 | 2025-09-05 | 2025-08-12 | 2025-08-20 | 2025-09-13 | 2025-08-20 | 404 | 404 |
| 000405 |  | Transporte de Material de Prestamo Cantera de Rio (Cuerpo de Terraplen) D>1km | 16d | 2025-08-12 | 2025-08-27 | 000404 SS | 24d | 0d | 5.4.5.10 | 926 | Cronograma Gantt_13 | 2025-08-12 | 2025-09-05 | 2025-08-12 | 2025-08-27 | 2025-09-20 | 2025-08-27 | 405 | 405 |
| 000402 |  | Transporte de Roca D<=1km | 7d | 2025-08-26 | 2025-09-01 | 000405 FS-2d | 40d | 0d | 5.4.5.7 | 923 | Cronograma Gantt_13 | 2025-08-26 | 2025-10-05 | 2025-08-26 | 2025-09-01 | 2025-10-11 | 2025-09-01 | 402 | 402 |
| 000403 |  | Transporte de Roca D>1km | 10d | 2025-08-26 | 2025-09-04 | 000402 SS | 40d | 16d | 5.4.5.8 | 924 | Cronograma Gantt_13 | 2025-08-26 | 2025-10-05 | 2025-08-26 | 2025-09-04 | 2025-10-14 | 2025-09-04 | 403 | 403 |
| 000406 |  | Transporte de Material Seleccionado para Zanja D<=1km | 1d | 2025-08-28 | 2025-08-28 | 000405 | 67d | 0d | 5.4.5.11 | 927 | Cronograma Gantt_13 | 2025-08-28 | 2025-11-03 | 2025-08-28 | 2025-08-28 | 2025-11-03 | 2025-08-28 | 406 | 406 |
| 000407 |  | Transporte de Material Seleccionado para Zanja D>1km | 1d | 2025-08-28 | 2025-08-28 | 000406 SS | 67d | 0d | 5.4.5.12 | 928 | Cronograma Gantt_13 | 2025-08-28 | 2025-11-03 | 2025-08-28 | 2025-08-28 | 2025-11-03 | 2025-08-28 | 407 | 407 |
| 000400 |  | Transporte de Material de Prestamo (Afirmado) D<=1km | 8d | 2025-08-29 | 2025-09-05 | 000407 | 72d | 0d | 5.4.5.5 | 921 | Cronograma Gantt_13 | 2025-08-29 | 2025-11-09 | 2025-08-29 | 2025-09-05 | 2025-11-16 | 2025-09-05 | 400 | 400 |
| 000401 |  | Transporte de Material de Prestamo (Afirmado) D>1km | 8d | 2025-08-29 | 2025-09-05 | 000400 SS | 72d | 18d | 5.4.5.6 | 922 | Cronograma Gantt_13 | 2025-08-29 | 2025-11-09 | 2025-08-29 | 2025-09-05 | 2025-11-16 | 2025-09-05 | 401 | 401 |
|  | 000408 | **Otros** |  | 2025-08-04 | 2025-08-10 |  |  |  |  |  |  |  |  |  |  |  |  |  |  |
|  | 000409 | **Via Carrozable** |  | 2025-08-04 | 2025-08-10 |  |  |  |  |  |  |  |  |  |  |  |  |  |  |
| 000410 |  | Material de Base para pavimento | 1d | 2025-08-04 | 2025-08-04 | 000372 | 99d | 0d | 5.4.6.1.1 | 1283 | Cronograma Gantt_13 | 2025-08-04 | 2025-11-11 | 2025-08-04 | 2025-08-04 | 2025-11-11 | 2025-08-04 | 410 | 410 |
| 000411 |  | Pavimento Emboquillado e=0.25m | 6d | 2025-08-05 | 2025-08-10 | 000410 | 99d | 75d | 5.4.6.1.2 | 1286 | Cronograma Gantt_13 | 2025-08-05 | 2025-11-12 | 2025-08-05 | 2025-08-10 | 2025-11-17 | 2025-08-10 | 411 | 411 |
|  | 000412 | **Mitigación Ambiental** |  | 2025-07-09 | 2025-07-10 |  |  |  |  |  |  |  |  |  |  |  |  |  |  |
| 000413 |  | Rescate camaron | 2d | 2025-07-09 | 2025-07-10 | 000021 | 2d | 0d | 5.4.7.1 | 1337 | Cronograma Gantt_13 | 2025-07-09 | 2025-07-11 | 2025-07-09 | 2025-07-10 | 2025-07-12 | 2025-07-10 | 413 | 413 |
|  | 000414 | **DI-PR-42-1-I / DI-PR-42-3-I** |  | 2025-08-04 | 2025-11-15 |  |  |  |  |  |  |  |  |  |  |  |  |  |  |
|  | 000415 | **Excavaciones** |  | 2025-08-06 | 2025-10-05 |  |  |  |  |  |  |  |  |  |  |  |  |  |  |
| 000416 |  | Desbroce | 2d | 2025-08-06 | 2025-08-07 | 000455 | 2d | 0d | 5.5.1.1 | 979 | Cronograma Gantt_13 | 2025-08-06 | 2025-08-08 | 2025-08-06 | 2025-08-07 | 2025-08-09 | 2025-08-07 | 416 | 416 |
| 000417 |  | Remocion de Dique Existente | 10d | 2025-08-08 | 2025-08-17 | 000416 | 14d | 0d | 5.5.1.2 | 980 | Cronograma Gantt_13 | 2025-08-08 | 2025-08-22 | 2025-08-08 | 2025-08-17 | 2025-08-31 | 2025-08-17 | 417 | 417 |
| 000418 |  | Excavacion de Cimentacion | 18d | 2025-08-18 | 2025-09-04 | 000417 | 14d | 0d | 5.5.1.3 | 981 | Cronograma Gantt_13 | 2025-08-18 | 2025-09-01 | 2025-08-18 | 2025-09-04 | 2025-09-18 | 2025-09-04 | 418 | 418 |
| 000420 |  | Excavacion de Uña | 10d | 2025-08-23 | 2025-09-01 | 000418 SS+5d | 77d | 75d | 5.5.1.5 | 983 | Cronograma Gantt_13 | 2025-08-23 | 2025-11-08 | 2025-08-23 | 2025-09-01 | 2025-11-17 | 2025-09-01 | 420 | 420 |
| 000422 |  | Conformacion de Material Excedente en DMO | 3d | 2025-08-28 | 2025-08-30 | 000439 | 79d | 77d | 5.5.1.7 | 985 | Cronograma Gantt_13 | 2025-08-28 | 2025-11-15 | 2025-08-28 | 2025-08-30 | 2025-11-17 | 2025-08-30 | 422 | 422 |
| 000419 |  | Perfilado y Conformacion de Plataforma de Fundacion | 5d | 2025-09-05 | 2025-09-09 | 000418 | 14d | 2d | 5.5.1.4 | 982 | Cronograma Gantt_13 | 2025-09-05 | 2025-09-19 | 2025-09-05 | 2025-09-09 | 2025-09-23 | 2025-09-09 | 419 | 419 |
| 000421 |  | Conformacion de Material Excedente en DME | 11d | 2025-09-25 | 2025-10-05 | 000441 | 43d | 41d | 5.5.1.6 | 984 | Cronograma Gantt_13 | 2025-09-25 | 2025-11-07 | 2025-09-25 | 2025-10-05 | 2025-11-17 | 2025-10-05 | 421 | 421 |

| ID | WBS | Activity | Duration | Start | Finish | Predecessors | Total float | Free float | MSP Outline Number | MSP Unique ID | MSP Project Name | Imported Early Start | Imported Late Start | Imported Start | Imported Early Finish | Imported Late Finish | Imported Finish | MSP ID | MSP Task Order |
| --- | --- | --- | --- | --- | --- | --- | --- | --- | --- | --- | --- | --- | --- | --- | --- | --- | --- | --- | --- |
|  | 000423 | **Rellenos** |  | 2025-09-12 | 2025-10-01 |  |  |  |  |  |  |  |  |  |  |  |  |  |  |
| 000424 |  | Relleno con Material Granular (incluye extraccion de material, zarandeo y combinado) | 2d | 2025-09-12 | 2025-09-13 | 000447, 000419 | 12d | 10d | 5.5.2.1 | 989 | Cronograma Gantt_13 | 2025-09-12 | 2025-09-24 | 2025-09-12 | 2025-09-13 | 2025-09-25 | 2025-09-13 | 424 | 424 |
| 000426 |  | Relleno con Material Seleccionado (incluye extraccion de material, zarandeo y combinado) | 7d | 2025-09-24 | 2025-09-30 | 000443, 000424 | 2d | 0d | 5.5.2.3 | 993 | Cronograma Gantt_13 | 2025-09-24 | 2025-09-26 | 2025-09-24 | 2025-09-30 | 2025-10-02 | 2025-09-30 | 426 | 426 |
| 000425 |  | Perfilado de Talud Dique | 1d | 2025-10-01 | 2025-10-01 | 000426 | 2d | 0d | 5.5.2.2 | 992 | Cronograma Gantt_13 | 2025-10-01 | 2025-10-03 | 2025-10-01 | 2025-10-01 | 2025-10-03 | 2025-10-01 | 425 | 425 |
|  | 000427 | **Geotextil** |  | 2025-10-02 | 2025-10-30 |  |  |  |  |  |  |  |  |  |  |  |  |  |  |
| 000428 |  | Instalacion de Geotextil 400gr/m2 | 21d | 2025-10-02 | 2025-10-22 | 000425 | 2d | 0d | 5.5.3.1 | 997 | Cronograma Gantt_13 | 2025-10-02 | 2025-10-04 | 2025-10-02 | 2025-10-22 | 2025-10-24 | 2025-10-22 | 428 | 428 |
| 000429 |  | Zanja de Anclaje | 13d | 2025-10-18 | 2025-10-30 | 000449, 000428 FS-5d | 18d | 16d | 5.5.3.2 | 998 | Cronograma Gantt_13 | 2025-10-18 | 2025-11-05 | 2025-10-18 | 2025-10-30 | 2025-11-17 | 2025-10-30 | 429 | 429 |
|  | 000430 | **Colocacion de Roca** |  | 2025-08-18 | 2025-11-15 |  |  |  |  |  |  |  |  |  |  |  |  |  |  |
| 000433 |  | Extraccion de Rocas Reutilizables | 9d | 2025-08-18 | 2025-08-26 | 000417 | 83d | 81d | 5.5.4.3 | 1003 | Cronograma Gantt_13 | 2025-08-18 | 2025-11-09 | 2025-08-18 | 2025-08-26 | 2025-11-17 | 2025-08-26 | 433 | 433 |
| 000436 |  | Rehabilitacion de Enrocados de Proteccion Existentes | 31d | 2025-08-18 | 2025-09-17 | 000417 | 61d | 59d | 5.5.4.6 | 1010 | Cronograma Gantt_13 | 2025-08-18 | 2025-10-18 | 2025-08-18 | 2025-09-17 | 2025-11-17 | 2025-09-17 | 436 | 436 |
| 000434 |  | Proteccion de Talud con Colchon Reno 6m Largo x e=0.30cm | 3d | 2025-10-02 | 2025-10-04 | 000425 | 44d | 42d | 5.5.4.4 | 1004 | Cronograma Gantt_13 | 2025-10-02 | 2025-11-15 | 2025-10-02 | 2025-10-04 | 2025-11-17 | 2025-10-04 | 434 | 434 |
| 000431 |  | Colocacion de Roca en Uña | 9d | 2025-10-23 | 2025-10-31 | 000445, 000428 | 2d | 0d | 5.5.4.1 | 1001 | Cronograma Gantt_13 | 2025-10-23 | 2025-10-25 | 2025-10-23 | 2025-10-31 | 2025-11-02 | 2025-10-31 | 431 | 431 |
| 000432 |  | Colocacion de Roca en Talud | 18d | 2025-10-25 | 2025-11-11 | 000431 SS+2d | 2d | 0d | 5.5.4.2 | 1002 | Cronograma Gantt_13 | 2025-10-25 | 2025-10-27 | 2025-10-25 | 2025-11-11 | 2025-11-13 | 2025-11-11 | 432 | 432 |
| 000435 |  | Colocación de Roca en Corona | 4d | 2025-11-12 | 2025-11-15 | 000432 | 2d | 0d | 5.5.4.5 | 1008 | Cronograma Gantt_13 | 2025-11-12 | 2025-11-14 | 2025-11-12 | 2025-11-15 | 2025-11-17 | 2025-11-15 | 435 | 435 |
|  | 000437 | **Transportes** |  | 2025-08-08 | 2025-10-15 |  |  |  |  |  |  |  |  |  |  |  |  |  |  |
| 000438 |  | Transporte de Material Organico (a DMO) D<=1km | 6d | 2025-08-08 | 2025-08-13 | 000416 | 2d | 0d | 5.5.5.1 | 1012 | Cronograma Gantt_13 | 2025-08-08 | 2025-08-10 | 2025-08-08 | 2025-08-13 | 2025-08-15 | 2025-08-13 | 438 | 438 |
| 000439 |  | Transporte de Material Organico (a DMO) D>1km | 20d | 2025-08-08 | 2025-08-27 | 000438 SS | 2d | 0d | 5.5.5.2 | 1013 | Cronograma Gantt_13 | 2025-08-08 | 2025-08-10 | 2025-08-08 | 2025-08-27 | 2025-08-29 | 2025-08-27 | 439 | 439 |
| 000446 |  | Transporte de Material de Prestamo Cantera de Rio (Cuerpo de Terraplen) D<=1km | 9d | 2025-08-28 | 2025-09-05 | 000439 | 2d | 0d | 5.5.5.9 | 1020 | Cronograma Gantt_13 | 2025-08-28 | 2025-08-30 | 2025-08-28 | 2025-09-05 | 2025-09-07 | 2025-09-05 | 446 | 446 |
| 000447 |  | Transporte de Material de Prestamo Cantera de Rio (Cuerpo de Terraplen) D>1km | 15d | 2025-08-28 | 2025-09-11 | 000446 SS | 2d | 0d | 5.5.5.10 | 1021 | Cronograma Gantt_13 | 2025-08-28 | 2025-08-30 | 2025-08-28 | 2025-09-11 | 2025-09-13 | 2025-09-11 | 447 | 447 |
| 000440 |  | Transporte de Material Excedente D<=1km | 17d | 2025-08-31 | 2025-09-16 | 000418 FS-5d | 43d | 0d | 5.5.5.3 | 1014 | Cronograma Gantt_13 | 2025-08-31 | 2025-10-13 | 2025-08-31 | 2025-09-16 | 2025-10-29 | 2025-09-16 | 440 | 440 |
| 000441 |  | Transporte de Material Excedente D>1km | 25d | 2025-08-31 | 2025-09-24 | 000440 SS | 43d | 0d | 5.5.5.4 | 1015 | Cronograma Gantt_13 | 2025-08-31 | 2025-10-13 | 2025-08-31 | 2025-09-24 | 2025-11-06 | 2025-09-24 | 441 | 441 |
| 000442 |  | Transporte de Material de Prestamo (Afirmado) D<=1km | 12d | 2025-09-12 | 2025-09-23 | 000447 | 2d | 0d | 5.5.5.5 | 1016 | Cronograma Gantt_13 | 2025-09-12 | 2025-09-14 | 2025-09-12 | 2025-09-23 | 2025-09-25 | 2025-09-23 | 442 | 442 |
| 000443 |  | Transporte de Material de Prestamo (Afirmado) D>1km | 12d | 2025-09-12 | 2025-09-23 | 000442 SS | 2d | 0d | 5.5.5.6 | 1017 | Cronograma Gantt_13 | 2025-09-12 | 2025-09-14 | 2025-09-12 | 2025-09-23 | 2025-09-25 | 2025-09-23 | 443 | 443 |
| 000444 |  | Transporte de Roca D<=1km | 34d | 2025-09-12 | 2025-10-15 | 000447 | 24d | 0d | 5.5.5.7 | 1018 | Cronograma Gantt_13 | 2025-09-12 | 2025-10-06 | 2025-09-12 | 2025-10-15 | 2025-11-08 | 2025-10-15 | 444 | 444 |
| 000445 |  | Transporte de Roca D>1km | 19d | 2025-09-12 | 2025-09-30 | 000444 SS | 24d | 22d | 5.5.5.8 | 1019 | Cronograma Gantt_13 | 2025-09-12 | 2025-10-06 | 2025-09-12 | 2025-09-30 | 2025-10-24 | 2025-09-30 | 445 | 445 |
| 000448 |  | Transporte de Material Seleccionado para Zanja D<=1km | 1d | 2025-09-12 | 2025-09-12 | 000447 | 53d | 0d | 5.5.5.11 | 1022 | Cronograma Gantt_13 | 2025-09-12 | 2025-11-04 | 2025-09-12 | 2025-09-12 | 2025-11-04 | 2025-09-12 | 448 | 448 |
| 000449 |  | Transporte de Material Seleccionado para Zanja D>1km | 1d | 2025-09-12 | 2025-09-12 | 000448 SS | 53d | 35d | 5.5.5.12 | 1023 | Cronograma Gantt_13 | 2025-09-12 | 2025-11-04 | 2025-09-12 | 2025-09-12 | 2025-11-04 | 2025-09-12 | 449 | 449 |

| ID | WBS | Activity | Duration | Start | Finish | Predecessors | Total float | Free float | MSP Outline Number | MSP Unique ID | MSP Project Name | Imported Early Start | Imported Late Start | Imported Start | Imported Early Finish | Imported Late Finish | Imported Finish | MSP ID | MSP Task Order |
| --- | --- | --- | --- | --- | --- | --- | --- | --- | --- | --- | --- | --- | --- | --- | --- | --- | --- | --- | --- |
|  | 000450 | **Otros** |  | 2025-08-08 | 2025-08-23 |  |  |  |  |  |  |  |  |  |  |  |  |  |  |
|  | 000451 | **Via Carrozable** |  | 2025-08-08 | 2025-08-23 |  |  |  |  |  |  |  |  |  |  |  |  |  |  |
| 000452 |  | Material de Base para pavimento | 1d | 2025-08-08 | 2025-08-08 | 000416 | 86d | 0d | 5.5.6.1.1 | 1070 | Cronograma Gantt_13 | 2025-08-08 | 2025-11-02 | 2025-08-08 | 2025-08-08 | 2025-11-02 | 2025-08-08 | 452 | 452 |
| 000453 |  | Pavimento Emboquillado e=0.25m | 15d | 2025-08-09 | 2025-08-23 | 000452 | 86d | 84d | 5.5.6.1.2 | 1071 | Cronograma Gantt_13 | 2025-08-09 | 2025-11-03 | 2025-08-09 | 2025-08-23 | 2025-11-17 | 2025-08-23 | 453 | 453 |
|  | 000454 | **Mitigación Ambiental** |  | 2025-08-04 | 2025-08-05 |  |  |  |  |  |  |  |  |  |  |  |  |  |  |
| 000455 |  | Rescate camaron | 2d | 2025-08-04 | 2025-08-05 | 000023 | 2d | 0d | 5.5.7.1 | 1339 | Cronograma Gantt_13 | 2025-08-04 | 2025-08-06 | 2025-08-04 | 2025-08-05 | 2025-08-07 | 2025-08-05 | 455 | 455 |
|  | 000456 | **DE-PR-39-I** |  | 2025-08-08 | 2025-11-11 |  |  |  |  |  |  |  |  |  |  |  |  |  |  |
|  | 000457 | **Excavaciones** |  | 2025-08-10 | 2025-09-13 |  |  |  |  |  |  |  |  |  |  |  |  |  |  |
| 000458 |  | Desbroce | 1d | 2025-08-10 | 2025-08-10 | 000520 | 6d | 0d | 5.6.1.1 | 1169 | Cronograma Gantt_13 | 2025-08-10 | 2025-08-16 | 2025-08-10 | 2025-08-10 | 2025-08-16 | 2025-08-10 | 458 | 458 |
| 000459 |  | Remocion de Dique Existente | 3d | 2025-08-11 | 2025-08-13 | 000458 | 6d | 0d | 5.6.1.2 | 1170 | Cronograma Gantt_13 | 2025-08-11 | 2025-08-17 | 2025-08-11 | 2025-08-13 | 2025-08-19 | 2025-08-13 | 459 | 459 |
| 000460 |  | Excavacion de Cimentacion | 14d | 2025-08-14 | 2025-08-27 | 000459 | 6d | 0d | 5.6.1.3 | 1171 | Cronograma Gantt_13 | 2025-08-14 | 2025-08-20 | 2025-08-14 | 2025-08-27 | 2025-09-02 | 2025-08-27 | 460 | 460 |
| 000465 |  | Excavacion Localizada - Sobreexcavacion | 4d | 2025-08-19 | 2025-08-22 | 000460 SS+5d | 87d | 81d | 5.6.1.8 | 1176 | Cronograma Gantt_13 | 2025-08-19 | 2025-11-14 | 2025-08-19 | 2025-08-22 | 2025-11-17 | 2025-08-22 | 465 | 465 |
| 000464 |  | Conformacion de Material Excedente en DMO | 1d | 2025-08-24 | 2025-08-24 | 000483 | 85d | 79d | 5.6.1.7 | 1175 | Cronograma Gantt_13 | 2025-08-24 | 2025-11-17 | 2025-08-24 | 2025-08-24 | 2025-11-17 | 2025-08-24 | 464 | 464 |
| 000461 |  | Perfilado y Conformacion de Plataforma de Fundacion | 2d | 2025-08-28 | 2025-08-29 | 000460 | 29d | 0d | 5.6.1.4 | 1172 | Cronograma Gantt_13 | 2025-08-28 | 2025-09-26 | 2025-08-28 | 2025-08-29 | 2025-09-27 | 2025-08-29 | 461 | 461 |
| 000462 |  | Excavacion de Uña | 6d | 2025-08-28 | 2025-09-02 | 000460 | 76d | 70d | 5.6.1.5 | 1173 | Cronograma Gantt_13 | 2025-08-28 | 2025-11-12 | 2025-08-28 | 2025-09-02 | 2025-11-17 | 2025-09-02 | 462 | 462 |
| 000463 |  | Conformacion de Material Excedente en DME | 8d | 2025-09-06 | 2025-09-13 | 000485 | 65d | 59d | 5.6.1.6 | 1174 | Cronograma Gantt_13 | 2025-09-06 | 2025-11-10 | 2025-09-06 | 2025-09-13 | 2025-11-17 | 2025-09-13 | 463 | 463 |
|  | 000466 | **Rellenos** |  | 2025-08-30 | 2025-11-02 |  |  |  |  |  |  |  |  |  |  |  |  |  |  |
| 000471 |  | Relleno con Material Seleccionado (incluye extraccion de material, zarandeo y combinado) | 4d | 2025-08-30 | 2025-09-02 | 000461 | 76d | 70d | 5.6.2.5 | 1183 | Cronograma Gantt_13 | 2025-08-30 | 2025-11-14 | 2025-08-30 | 2025-09-02 | 2025-11-17 | 2025-09-02 | 471 | 471 |
| 000467 |  | Relleno con Material Granular (incluye extraccion de material, zarandeo y combinado) | 3d | 2025-09-18 | 2025-09-20 | 000491, 000461 | 10d | 0d | 5.6.2.1 | 1179 | Cronograma Gantt_13 | 2025-09-18 | 2025-09-28 | 2025-09-18 | 2025-09-20 | 2025-09-30 | 2025-09-20 | 467 | 467 |
| 000470 |  | Perfilado de Talud Dique | 1d | 2025-09-21 | 2025-09-21 | 000467 | 10d | 0d | 5.6.2.4 | 1182 | Cronograma Gantt_13 | 2025-09-21 | 2025-10-01 | 2025-09-21 | 2025-09-21 | 2025-10-01 | 2025-09-21 | 470 | 470 |
| 000469 |  | Relleno Afirmado | 1d | 2025-10-17 | 2025-10-17 | 000487, 000475 | 10d | 4d | 5.6.2.3 | 1181 | Cronograma Gantt_13 | 2025-10-17 | 2025-10-27 | 2025-10-17 | 2025-10-17 | 2025-10-27 | 2025-10-17 | 469 | 469 |
| 000468 |  | Relleno sin Compactar | 2d | 2025-11-01 | 2025-11-02 | 000477 | 15d | 9d | 5.6.2.2 | 1180 | Cronograma Gantt_13 | 2025-11-01 | 2025-11-16 | 2025-11-01 | 2025-11-02 | 2025-11-17 | 2025-11-02 | 468 | 468 |
| 000472 |  | Grava para Drenaje | 1d | 2025-11-01 | 2025-11-01 | 000477 | 16d | 10d | 5.6.2.6 | 1184 | Cronograma Gantt_13 | 2025-11-01 | 2025-11-17 | 2025-11-01 | 2025-11-01 | 2025-11-17 | 2025-11-01 | 472 | 472 |
|  | 000473 | **Geotextil** |  | 2025-09-22 | 2025-10-16 |  |  |  |  |  |  |  |  |  |  |  |  |  |  |
| 000474 |  | Instalacion de Geotextil 400gr/m2 | 13d | 2025-09-22 | 2025-10-04 | 000470 | 10d | 0d | 5.6.3.1 | 1187 | Cronograma Gantt_13 | 2025-09-22 | 2025-10-02 | 2025-09-22 | 2025-10-04 | 2025-10-14 | 2025-10-04 | 474 | 474 |
| 000475 |  | Zanja de Anclaje | 12d | 2025-10-05 | 2025-10-16 | 000493, 000474 | 10d | 0d | 5.6.3.2 | 1188 | Cronograma Gantt_13 | 2025-10-05 | 2025-10-15 | 2025-10-05 | 2025-10-16 | 2025-10-26 | 2025-10-16 | 475 | 475 |

| ID | WBS | Activity | Duration | Start | Finish | Predecessors | Total float | Free float | MSP Outline Number | MSP Unique ID | MSP Project Name | Imported Early Start | Imported Late Start | Imported Start | Imported Early Finish | Imported Late Finish | Imported Finish | MSP ID | MSP Task Order |
| --- | --- | --- | --- | --- | --- | --- | --- | --- | --- | --- | --- | --- | --- | --- | --- | --- | --- | --- | --- |
|  | 000476 | **Colocacion de Roca** |  | 2025-08-14 | 2025-11-11 |  |  |  |  |  |  |  |  |  |  |  |  |  |  |
| 000479 |  | Extraccion de Rocas Reutilizables | 10d | 2025-08-14 | 2025-08-23 | 000459 | 86d | 80d | 5.6.4.3 | 1193 | Cronograma Gantt_13 | 2025-08-14 | 2025-11-08 | 2025-08-14 | 2025-08-23 | 2025-11-17 | 2025-08-23 | 479 | 479 |
| 000477 |  | Colocacion de Roca en Uña | 10d | 2025-10-22 | 2025-10-31 | 000489, 000469 | 6d | 0d | 5.6.4.1 | 1191 | Cronograma Gantt_13 | 2025-10-22 | 2025-10-28 | 2025-10-22 | 2025-10-31 | 2025-11-06 | 2025-10-31 | 477 | 477 |
| 000478 |  | Colocacion de Roca en Talud | 10d | 2025-11-01 | 2025-11-10 | 000477 | 6d | 0d | 5.6.4.2 | 1192 | Cronograma Gantt_13 | 2025-11-01 | 2025-11-07 | 2025-11-01 | 2025-11-10 | 2025-11-16 | 2025-11-10 | 478 | 478 |
| 000480 |  | Enrocado Talud Encachado con Concreto | 1d | 2025-11-11 | 2025-11-11 | 000478 | 6d | 0d | 5.6.4.4 | 1196 | Cronograma Gantt_13 | 2025-11-11 | 2025-11-17 | 2025-11-11 | 2025-11-11 | 2025-11-17 | 2025-11-11 | 480 | 480 |
|  | 000481 | **Transportes** |  | 2025-08-11 | 2025-10-21 |  |  |  |  |  |  |  |  |  |  |  |  |  |  |
| 000482 |  | Transporte de Material Organico (a DMO) D<=1km | 4d | 2025-08-11 | 2025-08-14 | 000458 | 85d | 0d | 5.6.5.1 | 1202 | Cronograma Gantt_13 | 2025-08-11 | 2025-11-04 | 2025-08-11 | 2025-08-14 | 2025-11-07 | 2025-08-14 | 482 | 482 |
| 000483 |  | Transporte de Material Organico (a DMO) D>1km | 13d | 2025-08-11 | 2025-08-23 | 000482 SS | 85d | 0d | 5.6.5.2 | 1203 | Cronograma Gantt_13 | 2025-08-11 | 2025-11-04 | 2025-08-11 | 2025-08-23 | 2025-11-16 | 2025-08-23 | 483 | 483 |
| 000484 |  | Transporte de Material Excedente D<=1km | 10d | 2025-08-26 | 2025-09-04 | 000460 FS-2d | 6d | 0d | 5.6.5.3 | 1204 | Cronograma Gantt_13 | 2025-08-26 | 2025-09-01 | 2025-08-26 | 2025-09-04 | 2025-09-10 | 2025-09-04 | 484 | 484 |
| 000485 |  | Transporte de Material Excedente D>1km | 11d | 2025-08-26 | 2025-09-05 | 000484 SS | 6d | 0d | 5.6.5.4 | 1205 | Cronograma Gantt_13 | 2025-08-26 | 2025-09-01 | 2025-08-26 | 2025-09-05 | 2025-09-11 | 2025-09-05 | 485 | 485 |
| 000490 |  | Transporte de Material de Prestamo Cantera de Rio (Cuerpo de Terraplen) D<=1km | 6d | 2025-09-06 | 2025-09-11 | 000485 | 6d | 0d | 5.6.5.9 | 1210 | Cronograma Gantt_13 | 2025-09-06 | 2025-09-12 | 2025-09-06 | 2025-09-11 | 2025-09-17 | 2025-09-11 | 490 | 490 |
| 000491 |  | Transporte de Material de Prestamo Cantera de Rio (Cuerpo de Terraplen) D>1km | 12d | 2025-09-06 | 2025-09-17 | 000490 SS | 6d | 0d | 5.6.5.10 | 1211 | Cronograma Gantt_13 | 2025-09-06 | 2025-09-12 | 2025-09-06 | 2025-09-17 | 2025-09-23 | 2025-09-17 | 491 | 491 |
| 000492 |  | Transporte de Material Seleccionado para Zanja D<=1km | 1d | 2025-09-18 | 2025-09-18 | 000491 | 6d | 0d | 5.6.5.11 | 1212 | Cronograma Gantt_13 | 2025-09-18 | 2025-09-24 | 2025-09-18 | 2025-09-18 | 2025-09-24 | 2025-09-18 | 492 | 492 |
| 000493 |  | Transporte de Material Seleccionado para Zanja D>1km | 1d | 2025-09-18 | 2025-09-18 | 000492 SS | 6d | 0d | 5.6.5.12 | 1213 | Cronograma Gantt_13 | 2025-09-18 | 2025-09-24 | 2025-09-18 | 2025-09-18 | 2025-09-24 | 2025-09-18 | 493 | 493 |
| 000486 |  | Transporte de Material de Prestamo (Afirmado) D<=1km | 7d | 2025-09-19 | 2025-09-25 | 000493 | 6d | 0d | 5.6.5.5 | 1206 | Cronograma Gantt_13 | 2025-09-19 | 2025-09-25 | 2025-09-19 | 2025-09-25 | 2025-10-01 | 2025-09-25 | 486 | 486 |
| 000487 |  | Transporte de Material de Prestamo (Afirmado) D>1km | 9d | 2025-09-19 | 2025-09-27 | 000486 SS | 6d | 0d | 5.6.5.6 | 1207 | Cronograma Gantt_13 | 2025-09-19 | 2025-09-25 | 2025-09-19 | 2025-09-27 | 2025-10-03 | 2025-09-27 | 487 | 487 |
| 000488 |  | Transporte de Roca D<=1km | 20d | 2025-09-28 | 2025-10-17 | 000487 | 6d | 0d | 5.6.5.7 | 1208 | Cronograma Gantt_13 | 2025-09-28 | 2025-10-04 | 2025-09-28 | 2025-10-17 | 2025-10-23 | 2025-10-17 | 488 | 488 |
| 000489 |  | Transporte de Roca D>1km | 9d | 2025-10-13 | 2025-10-21 | 000488 FS-5d | 6d | 0d | 5.6.5.8 | 1209 | Cronograma Gantt_13 | 2025-10-13 | 2025-10-19 | 2025-10-13 | 2025-10-21 | 2025-10-27 | 2025-10-21 | 489 | 489 |
|  | 000494 | **Obras Civiles (Interferencias)** |  | 2025-08-14 | 2025-09-24 |  |  |  |  |  |  |  |  |  |  |  |  |  |  |
| 000495 |  | Trazo y replanteo de interferencia | 1d | 2025-08-14 | 2025-08-14 | 000459 | 54d | 0d | 5.6.6.1 | 1215 | Cronograma Gantt_13 | 2025-08-14 | 2025-10-07 | 2025-08-14 | 2025-08-14 | 2025-10-07 | 2025-08-14 | 495 | 495 |
| 000498 |  | Limpieza de terreno manual | 4d | 2025-08-15 | 2025-08-18 | 000495 | 54d | 0d | 5.6.6.4 | 1218 | Cronograma Gantt_13 | 2025-08-15 | 2025-10-08 | 2025-08-15 | 2025-08-18 | 2025-10-11 | 2025-08-18 | 498 | 498 |
| 000499 |  | Excavaciones no clasificada para estructuras | 1d | 2025-08-19 | 2025-08-19 | 000498 | 54d | 0d | 5.6.6.5 | 1219 | Cronograma Gantt_13 | 2025-08-19 | 2025-10-12 | 2025-08-19 | 2025-08-19 | 2025-10-12 | 2025-08-19 | 499 | 499 |
| 000500 |  | Excavacion no clasificada de zanja | 2d | 2025-08-19 | 2025-08-20 | 000498 | 84d | 0d | 5.6.6.6 | 1220 | Cronograma Gantt_13 | 2025-08-19 | 2025-11-11 | 2025-08-19 | 2025-08-20 | 2025-11-12 | 2025-08-20 | 500 | 500 |
| 000501 |  | Relleno estructural | 4d | 2025-08-20 | 2025-08-23 | 000499 | 54d | 0d | 5.6.6.7 | 1221 | Cronograma Gantt_13 | 2025-08-20 | 2025-10-13 | 2025-08-20 | 2025-08-23 | 2025-10-16 | 2025-08-23 | 501 | 501 |
| 000496 |  | Desvío provisional con tubería | 1d | 2025-08-21 | 2025-08-21 | 000500 | 84d | 0d | 5.6.6.2 | 1216 | Cronograma Gantt_13 | 2025-08-21 | 2025-11-13 | 2025-08-21 | 2025-08-21 | 2025-11-13 | 2025-08-21 | 496 | 496 |
| 000513 |  | Cama de arena e=0.20m | 1d | 2025-08-21 | 2025-08-21 | 000500 | 87d | 0d | 5.6.6.19 | 1234 | Cronograma Gantt_13 | 2025-08-21 | 2025-11-16 | 2025-08-21 | 2025-08-21 | 2025-11-16 | 2025-08-21 | 513 | 513 |
| 000497 |  | Desvío provisional en tierras | 2d | 2025-08-22 | 2025-08-23 | 000496 | 84d | 0d | 5.6.6.3 | 1217 | Cronograma Gantt_13 | 2025-08-22 | 2025-11-14 | 2025-08-22 | 2025-08-23 | 2025-11-15 | 2025-08-23 | 497 | 497 |
| 000514 |  | Tubería HDPE Corrugada Ø=900mm (Suministro e instalación) | 1d | 2025-08-22 | 2025-08-22 | 000513 | 87d | 81d | 5.6.6.20 | 1235 | Cronograma Gantt_13 | 2025-08-22 | 2025-11-17 | 2025-08-22 | 2025-08-22 | 2025-11-17 | 2025-08-22 | 514 | 514 |
| 000502 |  | Suministro de roca (Alcantarillas) | 1d | 2025-08-24 | 2025-08-24 | 000497 | 84d | 0d | 5.6.6.8 | 1222 | Cronograma Gantt_13 | 2025-08-24 | 2025-11-16 | 2025-08-24 | 2025-08-24 | 2025-11-16 | 2025-08-24 | 502 | 502 |
| 000504 |  | Concreto de Nivelacion (f'c=100 kg/cm2) | 1d | 2025-08-24 | 2025-08-24 | 000501 | 54d | 0d | 5.6.6.10 | 1224 | Cronograma Gantt_13 | 2025-08-24 | 2025-10-17 | 2025-08-24 | 2025-08-24 | 2025-10-17 | 2025-08-24 | 504 | 504 |
| 000503 |  | Colocación de roca en uña (Alcantarillas) | 1d | 2025-08-25 | 2025-08-25 | 000502 | 84d | 78d | 5.6.6.9 | 1223 | Cronograma Gantt_13 | 2025-08-25 | 2025-11-17 | 2025-08-25 | 2025-08-25 | 2025-11-17 | 2025-08-25 | 503 | 503 |
| 000505 |  | Concreto Clase F (f'c=140 kg/cm2) | 2d | 2025-08-25 | 2025-08-26 | 000504 | 54d | 0d | 5.6.6.11 | 1225 | Cronograma Gantt_13 | 2025-08-25 | 2025-10-18 | 2025-08-25 | 2025-08-26 | 2025-10-19 | 2025-08-26 | 505 | 505 |
| 000510 |  | Acero de refuerzo f'y=4200kg/cm2 | 12d | 2025-08-27 | 2025-09-07 | 000505 | 54d | 0d | 5.6.6.16 | 1230 | Cronograma Gantt_13 | 2025-08-27 | 2025-10-20 | 2025-08-27 | 2025-09-07 | 2025-10-31 | 2025-09-07 | 510 | 510 |
| 000506 |  | Concreto Clase C (f'c=280 kg/cm2) Premezclado - Cimientos reforzados | 1d | 2025-09-08 | 2025-09-08 | 000510 | 54d | 0d | 5.6.6.12 | 1226 | Cronograma Gantt_13 | 2025-09-08 | 2025-11-01 | 2025-09-08 | 2025-09-08 | 2025-11-01 | 2025-09-08 | 506 | 506 |
| 000508 |  | Encofrado y Desencofrado Caravista | 4d | 2025-09-09 | 2025-09-12 | 000506 | 66d | 60d | 5.6.6.14 | 1228 | Cronograma Gantt_13 | 2025-09-09 | 2025-11-14 | 2025-09-09 | 2025-09-12 | 2025-11-17 | 2025-09-12 | 508 | 508 |
| 000509 |  | Encofrado y Desencofrado Cara Oculta | 7d | 2025-09-09 | 2025-09-15 | 000506 | 54d | 0d | 5.6.6.15 | 1229 | Cronograma Gantt_13 | 2025-09-09 | 2025-11-02 | 2025-09-09 | 2025-09-15 | 2025-11-08 | 2025-09-15 | 509 | 509 |
| 000507 |  | Concreto Clase C (f'c=280 kg/cm2) Premezclado - Muros de contencion | 2d | 2025-09-16 | 2025-09-17 | 000509 | 54d | 0d | 5.6.6.13 | 1227 | Cronograma Gantt_13 | 2025-09-16 | 2025-11-09 | 2025-09-16 | 2025-09-17 | 2025-11-10 | 2025-09-17 | 507 | 507 |
| 000511 |  | Emboquillado de piedra e=0.20m | 1d | 2025-09-18 | 2025-09-18 | 000507 | 60d | 54d | 5.6.6.17 | 1231 | Cronograma Gantt_13 | 2025-09-18 | 2025-11-17 | 2025-09-18 | 2025-09-18 | 2025-11-17 | 2025-09-18 | 511 | 511 |
| 000512 |  | Emboquillado de piedra e=0.30m | 2d | 2025-09-18 | 2025-09-19 | 000507 | 59d | 53d | 5.6.6.18 | 1232 | Cronograma Gantt_13 | 2025-09-18 | 2025-11-16 | 2025-09-18 | 2025-09-19 | 2025-11-17 | 2025-09-19 | 512 | 512 |
| 000515 |  | Sello en juntas | 1d | 2025-09-18 | 2025-09-18 | 000507 | 54d | 0d | 5.6.6.21 | 1238 | Cronograma Gantt_13 | 2025-09-18 | 2025-11-11 | 2025-09-18 | 2025-09-18 | 2025-11-11 | 2025-09-18 | 515 | 515 |
| 000518 |  | Suministro e Instalación de geotextil | 1d | 2025-09-18 | 2025-09-18 | 000507 | 60d | 54d | 5.6.6.24 | 1241 | Cronograma Gantt_13 | 2025-09-18 | 2025-11-17 | 2025-09-18 | 2025-09-18 | 2025-11-17 | 2025-09-18 | 518 | 518 |
| 000516 |  | Waterstop (anillos de estanqueidad) | 1d | 2025-09-19 | 2025-09-19 | 000515 | 54d | 0d | 5.6.6.22 | 1239 | Cronograma Gantt_13 | 2025-09-19 | 2025-11-12 | 2025-09-19 | 2025-09-19 | 2025-11-12 | 2025-09-19 | 516 | 516 |
| 000517 |  | Pintura bituminosa | 5d | 2025-09-20 | 2025-09-24 | 000516 | 54d | 48d | 5.6.6.23 | 1240 | Cronograma Gantt_13 | 2025-09-20 | 2025-11-13 | 2025-09-20 | 2025-09-24 | 2025-11-17 | 2025-09-24 | 517 | 517 |

| ID | WBS | Activity | Duration | Start | Finish | Predecessors | Total float | Free float | MSP Outline Number | MSP Unique ID | MSP Project Name | Imported Early Start | Imported Late Start | Imported Start | Imported Early Finish | Imported Late Finish | Imported Finish | MSP ID | MSP Task Order |
| --- | --- | --- | --- | --- | --- | --- | --- | --- | --- | --- | --- | --- | --- | --- | --- | --- | --- | --- | --- |
|  | 000519 | **Mitigación Ambiental** |  | 2025-08-08 | 2025-08-09 |  |  |  |  |  |  |  |  |  |  |  |  |  |  |
| 000520 |  | Rescate camaron | 2d | 2025-08-08 | 2025-08-09 | 000025 | 6d | 0d | 5.6.7.1 | 1341 | Cronograma Gantt_13 | 2025-08-08 | 2025-08-14 | 2025-08-08 | 2025-08-09 | 2025-08-15 | 2025-08-09 | 520 | 520 |
